# SUB PROYECTO A3 - CRONOGRAMA OFERTA

How a schedule from Primavera P6 changed from version to version. A marks actual dates.

## Version 1 (data date 2023-04-25, saved 2023-04-14, file OHLA.A3.xer)

| ID | WBS | Task | Duration | Start | Finish | Predecessors | Total float | Constraint |
| --- | --- | --- | --- | --- | --- | --- | --- | --- |
|  | 000 | **GENERALES** |  | 2023-04-25 | 2023-12-02 |  |  |  |
|  | M | **GESTION** |  | 2023-04-25 | 2023-05-02 |  |  |  |
|  | 10 | **CONTROL DE PROYECTOS** |  | 2023-04-25 | 2023-05-02 |  |  |  |
|  | 01 | **HITOS DE CONTROL** |  | 2023-04-25 | 2023-05-02 |  |  |  |
|  | 01 | **HITOS CLAVE** |  | 2023-04-25 | 2023-05-02 |  |  |  |
| M.10.01.01.11 |  | Carta de Adjudicación | 0d | 2023-04-25 | 2023-04-25 |  | 0d |  |
| M.10.01.01.12 |  | KOM | 0d | 2023-05-02 | 2023-05-02 | M.10.01.01.11 SS+7d | 0d |  |
|  | C | **CONSTRUCCION** |  | 2023-04-25 | 2023-12-02 |  |  |  |
|  | 90 | **TRABAJOS PRELIMINARES** |  | 2023-04-25 | 2023-12-02 |  |  |  |
|  | 02 | **COSTOS DEL CONTRATISTA GENERAL** |  | 2023-05-02 | 2023-05-17 |  |  |  |
|  | 01 | **MOVILIZACIÓN** |  | 2023-05-02 | 2023-05-17 |  |  |  |
| C.90.02.01.11 |  | Movilización de equipos - Movimiento de Tierras | 16d | 2023-05-02 | 2023-05-17 | M.10.01.01.12 SS | 0d |  |
|  | 03 | **GASTOS GENERALES** |  | 2023-04-25 | 2023-12-02 |  |  |  |
| C.90.03.11 |  | Gastos Generales | 222d | 2023-04-25 | 2023-12-02 | M.10.01.01.11 SS | 0d |  |
|  | 501 | **DEFENSAS RIBEREÑAS** |  | 2023-05-18 | 2023-12-02 |  |  |  |
|  | M | **GESTION** |  | 2023-05-18 | 2023-12-02 |  |  |  |
|  | 10 | **CONTROL DE PROYECTOS** |  | 2023-05-18 | 2023-12-02 |  |  |  |
|  | 01 | **HITOS DE CONTROL** |  | 2023-05-18 | 2023-12-02 |  |  |  |
|  | 01 | **HITOS CLAVE** |  | 2023-05-18 | 2023-12-02 |  |  |  |
| M.10.01.01.13 |  | Fecha Clave 1: Acceso al Sitio | 0d | 2023-05-18 | 2023-05-18 | M.10.01.01.12 SS+16d | 0d |  |
| M.10.01.01.14 |  | Fecha clave 2: Inicio de excavación | 0d | 2023-05-23 | 2023-05-23 | M.10.01.01.13 SS+5d | 172d |  |
| M.10.01.01.15 |  | Fecha Clave 3: Inicio de rellenos | 0d | 2023-06-14 | 2023-06-14 | M.10.01.01.14 SS+22d | 172d |  |
| M.10.01.01.16 |  | Fecha Clave 4: Culminación | 0d | 2023-12-02 | 2023-12-02 | M.10.01.01.13 SF+199d | 0d |  |
|  | 02 | **HITOS PLANIFICADOS** |  | 2023-05-18 | 2023-12-02 |  |  |  |
| M.10.01.02.11 |  | Hito Planificado 1: Acceso al sitio | 0d | 2023-05-18 | 2023-05-18 | C.90.02.01.11 | 0d |  |
| M.10.01.02.12 |  | Hito Planificado 2: Inicio de excavación | 0d | 2023-05-23 | 2023-05-23 | C.70.10.02.2.11 SS | 194d |  |
| M.10.01.02.13 |  | Hito Planificado 3: Inicio de rellenos | 0d | 2023-06-14 | 2023-06-14 | C.70.10.01.14 SS | 172d |  |
| M.10.01.02.14 |  | Hito Planificado 4: Culminación | 0d | 2023-12-02 | 2023-12-02 | C.90.03.11 FF, C.90.02.08.11 FF, C.90.02.06.11 FF, C.90.02.05.11 FF, T.20.12 FF, C.90.02.02.11 FF, C.90.02.03.11 FF | 0d |  |
|  | C | **CONSTRUCCIÓN** |  | 2023-05-18 | 2023-12-02 |  |  |  |
|  | 90 | **TRABAJOS PRELIMINARES** |  | 2023-05-18 | 2023-12-02 |  |  |  |
|  | 02 | **COSTOS DEL CONTRATISTA GENERAL** |  | 2023-05-18 | 2023-12-02 |  |  |  |
|  | 01 | **MOVILIZACIÓN** |  | 2023-09-22 | 2023-10-05 |  |  |  |
| C.90.02.01.12 |  | Movilización de equipos - Paisajismo | 14d | 2023-09-22 | 2023-10-05 | C.70.10.04.15 | 26d |  |
|  | 02 | **TRAZO Y REPLANTEO** |  | 2023-05-18 | 2023-12-02 |  |  |  |
| C.90.02.02.11 |  | Topografia y georreferenciación | 199d | 2023-05-18 | 2023-12-02 | M.10.01.01.13 SS | 0d |  |
| C.90.02.02.12 |  | Trazo y replanteo preliminar - Paisajismo | 29d | 2023-10-06 | 2023-11-03 | C.70.03.01.11 SS | 26d |  |
|  | 03 | **SEGURIDAD INDUSTRIAL Y SALUD OCUPACIONAL** |  | 2023-05-18 | 2023-12-02 |  |  |  |
| C.90.02.03.11 |  | Seguridad y salud ocupacional | 199d | 2023-05-18 | 2023-12-02 | M.10.01.01.13 SS | 0d |  |
|  | 04 | **INSTALACIONES PROVISIONALES PARA OBRA** |  | 2023-05-18 | 2023-11-25 |  |  |  |
| C.90.02.04.11 |  | Instalación de facilidades de obra | 15d | 2023-05-18 | 2023-06-01 | C.90.02.01.11 | 182d |  |
| C.90.02.04.12 |  | Colocación de Cartel de Identificación | 2d | 2023-06-02 | 2023-06-03 | C.90.02.04.11 | 182d |  |
| C.90.02.04.13 |  | Gastos de facilidades de obra | 175d | 2023-06-04 | 2023-11-25 | C.90.02.04.12 | 0d |  |
|  | 05 | **GESTIÓN DE RESIDUOS** |  | 2023-05-18 | 2023-12-02 |  |  |  |
| C.90.02.05.12 |  | Acondicionamiento de DME | 175d | 2023-05-18 | 2023-11-08 | M.10.01.02.11 SS | 0d |  |
| C.90.02.05.11 |  | Restauración de áreas de instalaciones provisionales | 24d | 2023-11-09 | 2023-12-02 | C.90.02.05.12 | 0d | as late as possible |
|  | 06 | **PLAN DE VIGILANCIA, PREVENCIÓN Y CONTROL COVID 19** |  | 2023-05-18 | 2023-12-02 |  |  |  |
| C.90.02.06.11 |  | Implementación del Plan para la vigilancia, prevención y control de COVID -19 | 199d | 2023-05-18 | 2023-12-02 | M.10.01.02.11 SS, M.10.01.01.14 SS | 0d |  |
|  | 07 | **TRANSPORTE** |  | 2023-05-23 | 2023-10-19 |  |  |  |
| C.90.02.07.15 |  | Transporte de material excedente < 1km | 81d | 2023-05-23 | 2023-08-11 | M.10.01.02.12 SS | 59d |  |
| C.90.02.07.16 |  | Transporte de material excedente >1km | 81d | 2023-05-23 | 2023-08-11 | M.10.01.02.12 SS | 59d |  |
| C.90.02.07.13 |  | Transporte de roca <1km | 114d | 2023-06-22 | 2023-10-13 | C.70.10.01.17 SS | 37d |  |
| C.90.02.07.14 |  | Transporte de roca >1km | 71d | 2023-06-22 | 2023-08-31 | C.70.10.01.17 SS | 37d |  |
| C.90.02.07.11 |  | Transporte de material granular < 1km | 114d | 2023-06-28 | 2023-10-19 | C.70.11.01.13 SS | 37d |  |
| C.90.02.07.12 |  | Transporte de material granular >1km | 114d | 2023-06-28 | 2023-10-19 | C.70.11.01.13 SS | 37d |  |
|  | 08 | **MANTENIMIENTO DE TRANSITO Y SEGURIDAD VIAL** |  | 2023-05-18 | 2023-12-02 |  |  |  |
| C.90.02.08.11 |  | Mantenimiento de tránsito y seguridad vial | 199d | 2023-05-18 | 2023-12-02 | M.10.01.02.11 SS | 0d |  |
|  | 80 | **FACILIDADES DE OBRA** |  | 2023-05-22 | 2023-06-22 |  |  |  |
|  | 02 | **DEMOLICIONES** |  | 2023-05-24 | 2023-06-22 |  |  |  |
| C.80.02.16 |  | Demolición de sifon invertido | 1d | 2023-05-24 | 2023-05-24 | C.70.01.01.12 SS, C.70.01.01.16 SS | 156d |  |
| C.80.02.11 |  | Demolición de estructuras existentes - Punto de agua 1 | 1d | 2023-06-01 | 2023-06-01 | C.70.02.01.01.12 | 167d |  |
| C.80.02.12 |  | Demolición de estructuras existentes - Punto de agua 2 | 1d | 2023-06-02 | 2023-06-02 | C.80.02.11 | 167d |  |
| C.80.02.13 |  | Demolición de estructuras existentes - Punto de agua 3 | 2d | 2023-06-03 | 2023-06-04 | C.80.02.12 | 167d |  |
| C.80.02.14 |  | Demolición de canal 1 | 8d | 2023-06-08 | 2023-06-15 | C.70.01.01.17, C.70.01.01.15 | 29d |  |
| C.80.02.15 |  | Demolición de canal 3 | 5d | 2023-06-18 | 2023-06-22 | C.70.01.01.12, C.70.01.01.16 | 132d |  |
|  | 04 | **OBRAS DE DESVIO TEMPORAL** |  | 2023-05-22 | 2023-06-19 |  |  |  |
| C.80.02.19 |  | Conformación de desvió en cauce de río Dique A3-D-02 - Sector 2 | 3d | 2023-05-22 | 2023-05-24 | C.70.01.01.14 SS | 69d |  |
| C.80.02.17 |  | Conformación de desvió en cauce de río Dique A3-D-01 | 2d | 2023-05-25 | 2023-05-26 | C.70.01.01.12 SS+1d | 105d |  |
| C.80.02.18 |  | Conformación de desvió en cauce de río Dique A3-D-02 - Sector 1 | 2d | 2023-06-01 | 2023-06-02 | C.70.01.01.13 | 77d |  |
| C.80.02.23 |  | Conformación de desvió en cauce de río Dique A3-I-03 - Sector 1 | 3d | 2023-06-04 | 2023-06-06 | C.70.01.01.18 | 48d |  |
| C.80.02.24 |  | Conformación de desvió en cauce de río Dique A3-I-03 - Sector 2 | 4d | 2023-06-05 | 2023-06-08 | C.70.01.01.19 | 38d |  |

| ID | WBS | Task | Duration | Start | Finish | Predecessors | Total float |
| --- | --- | --- | --- | --- | --- | --- | --- |
| C.80.02.20 |  | Conformación de desvió en cauce de río Dique A3-D-02 - Sector 3 | 4d | 2023-06-08 | 2023-06-11 | C.70.01.01.15 | 2d |
| C.80.02.22 |  | Conformación de desvió en cauce de río Dique A3-I-02 | 2d | 2023-06-08 | 2023-06-09 | C.70.01.01.17 | 0d |
| C.80.02.21 |  | Conformación de desvió en cauce de río Dique A3-I-01 | 2d | 2023-06-18 | 2023-06-19 | C.70.01.01.16 | 58d |
|  | 70 | **OBRAS EXTERIORES** |  | 2023-05-18 | 2023-11-03 |  |  |
|  | 01 | **PREPARACION DEL SITIO** |  | 2023-05-18 | 2023-07-04 |  |  |
|  | 01 | **LIMPIEZA** |  | 2023-05-18 | 2023-06-17 |  |  |
| C.70.01.01.11 |  | Roce y limpieza de vías | 5d | 2023-05-18 | 2023-05-22 | M.10.01.01.13 SS | 168d |
| C.70.01.01.14 |  | Desbroce y limpieza Dique A3-D-02 - Sector 2 | 15d | 2023-05-22 | 2023-06-05 | C.70.02.01.01.11 | 69d |
| C.70.01.01.15 |  | Desbroce y limpieza Dique A3-D-02 - Sector 3 | 17d | 2023-05-22 | 2023-06-07 | C.70.02.01.01.11 | 2d |
| C.70.01.01.18 |  | Desbroce y limpieza Dique A3-I-03 - Sector 1 | 13d | 2023-05-22 | 2023-06-03 | C.70.02.01.01.11 | 48d |
| C.70.01.01.19 |  | Desbroce y limpieza Dique A3-I-03 - Sector 2 | 14d | 2023-05-22 | 2023-06-04 | C.70.02.01.01.11 | 38d |
| C.70.01.01.12 |  | Desbroce y limpieza Dique A3-D-01 | 7d | 2023-05-24 | 2023-05-30 | C.70.02.01.01.14 | 105d |
| C.70.01.01.13 |  | Desbroce y limpieza Dique A3-D-02 - Sector 1 | 8d | 2023-05-24 | 2023-05-31 | C.70.02.01.01.14 | 77d |
| C.70.01.01.16 |  | Desbroce y limpieza Dique A3-I-01 | 25d | 2023-05-24 | 2023-06-17 | C.70.02.01.01.14 | 58d |
| C.70.01.01.17 |  | Desbroce y limpieza Dique A3-I-02 | 15d | 2023-05-24 | 2023-06-07 | C.70.02.01.01.14 | 0d |
|  | 02 | **DESCOLMATACIÓN** |  | 2023-05-22 | 2023-07-04 |  |  |
| C.70.01.02.13 |  | Descolmatación Dique A3-D-02 - Sector 2 | 8d | 2023-05-22 | 2023-05-29 | C.80.02.19 SS | 69d |
| C.70.01.02.21 |  | Relleno no estructural Dique A3-D-02 - Sector 2 | 3d | 2023-05-22 | 2023-05-24 | C.70.01.02.13 SS | 69d |
| C.70.01.02.11 |  | Descolmatación Dique A3-D-01 | 4d | 2023-05-26 | 2023-05-29 | C.80.02.17 SS+1d | 105d |
| C.70.01.02.19 |  | Relleno no estructural Dique A3-D-01 | 2d | 2023-05-27 | 2023-05-28 | C.70.01.02.11 SS+1d | 105d |
| C.70.01.02.12 |  | Descolmatación Dique A3-D-02 - Sector 1 | 4d | 2023-06-03 | 2023-06-06 | C.80.02.18 | 77d |
| C.70.01.02.17 |  | Descolmatación Dique A3-I-03 - Sector 1 | 7d | 2023-06-07 | 2023-06-13 | C.80.02.23 | 48d |
| C.70.01.02.20 |  | Relleno no estructural Dique A3-D-02 - Sector 1 | 2d | 2023-06-07 | 2023-06-08 | C.70.01.02.12 | 77d |
| C.70.01.02.18 |  | Descolmatación Dique A3-I-03 - Sector 2 | 8d | 2023-06-09 | 2023-06-16 | C.80.02.24 | 38d |
| C.70.01.02.16 |  | Descolmatación Dique A3-I-02 | 8d | 2023-06-10 | 2023-06-17 | C.80.02.22 | 0d |
| C.70.01.02.14 |  | Descolmatación Dique A3-D-02 - Sector 3 | 9d | 2023-06-12 | 2023-06-20 | C.80.02.20 | 2d |
| C.70.01.02.25 |  | Relleno no estructural Dique A3-I-03 - Sector 1 | 3d | 2023-06-14 | 2023-06-16 | C.70.01.02.17 | 48d |
| C.70.01.02.26 |  | Relleno no estructural Dique A3-I-03 - Sector 2 | 4d | 2023-06-17 | 2023-06-20 | C.70.01.02.18 | 38d |
| C.70.01.02.24 |  | Relleno no estructural Dique A3-I-02 | 2d | 2023-06-18 | 2023-06-19 | C.70.01.02.16 | 0d |
| C.70.01.02.15 |  | Descolmatación Dique A3-I-01 | 13d | 2023-06-20 | 2023-07-02 | C.80.02.21 | 58d |
| C.70.01.02.22 |  | Relleno no estructural Dique A3-D-02 - Sector 3 | 4d | 2023-06-21 | 2023-06-24 | C.70.01.02.14 | 2d |
| C.70.01.02.23 |  | Relleno no estructural Dique A3-I-01 | 2d | 2023-07-03 | 2023-07-04 | C.70.01.02.15 | 58d |
|  | 02 | **CAMINOS PROVISIONALES** |  | 2023-05-18 | 2023-06-11 |  |  |
|  | 01 | **MEJORAMIENTO DE VIAS** |  | 2023-05-18 | 2023-06-11 |  |  |
|  | 01 | **MEJORAMIENTO DE VIAS EXISTENTES** |  | 2023-05-18 | 2023-05-31 |  |  |
| C.70.02.01.01.11 |  | Mejoramiento de vías - Vía Acceso AN-879 | 4d | 2023-05-18 | 2023-05-21 | M.10.01.02.11 SS | 0d |
| C.70.02.01.01.14 |  | Mejoramiento de vías - EMPALME CHACHAPOYAS | 2d | 2023-05-22 | 2023-05-23 | C.70.02.01.01.11 | 0d |
| C.70.02.01.01.13 |  | Mejoramiento de vías - EMPALME CANAL - DME-3A | 4d | 2023-05-24 | 2023-05-27 | C.70.02.01.01.14, C.70.01.01.11 | 167d |
| C.70.02.01.01.12 |  | Mejoramiento de vías - FA-07 --AN-879 | 4d | 2023-05-28 | 2023-05-31 | C.70.02.01.01.13 | 167d |
|  | 02 | **REPOSICIÓN DE ESTRUCTURAS EXISTENTES** |  | 2023-06-02 | 2023-06-07 |  |  |
|  | 01 | **PUNTO DE AGUA 1** |  | 2023-06-02 | 2023-06-03 |  |  |
| C.70.02.01.02.01.11 |  | Suministro de paneles de C°A° | 2d | 2023-06-02 | 2023-06-03 | C.80.02.11 | 175d |
|  | 02 | **PUNTO DE AGUA 2** |  | 2023-06-03 | 2023-06-03 |  |  |
| C.70.02.01.02.02.11 |  | Suministro de paneles de C°A° | 1d | 2023-06-03 | 2023-06-03 | C.80.02.12 | 175d |
|  | 03 | **PUNTO DE AGUA 3** |  | 2023-06-05 | 2023-06-07 |  |  |
| C.70.02.01.02.03.11 |  | Reposición de pase agua tubo HDPE 36" | 3d | 2023-06-05 | 2023-06-07 | C.80.02.13 | 167d |
| C.70.02.01.02.03.12 |  | Reposición de pase agua tubo HDPE 18" | 0d | 2023-06-05 | 2023-06-05 | C.80.02.13 | 170d |
|  | 03 | **CABEZAL DE ENTRADA Y SALIDA** |  | 2023-06-08 | 2023-06-11 |  |  |
| C.70.02.01.03.11 |  | Encofrado recto cabeza de entrada | 1d | 2023-06-08 | 2023-06-08 | C.70.02.01.02.03.11, C.70.02.01.02.03.12 | 167d |
| C.70.02.01.03.12 |  | Concreto cabezal de entrada | 1d | 2023-06-09 | 2023-06-09 | C.70.02.01.03.11 | 167d |
| C.70.02.01.03.14 |  | Encofrado recto cabeza de salida | 1d | 2023-06-09 | 2023-06-09 | C.70.02.01.03.11 | 167d |
| C.70.02.01.03.13 |  | Desconfrado de cabezal de entrada | 1d | 2023-06-10 | 2023-06-10 | C.70.02.01.03.12 | 167d |
| C.70.02.01.03.15 |  | Concreto cabezal de salida | 1d | 2023-06-10 | 2023-06-10 | C.70.02.01.03.12, C.70.02.01.03.14 | 167d |
| C.70.02.01.03.16 |  | Desconfrado de cabezal de salida | 1d | 2023-06-11 | 2023-06-11 | C.70.02.01.03.13, C.70.02.01.03.15 | 167d |
|  | 03 | **PLANTACIÓN Y PAISAJISMO** |  | 2023-10-06 | 2023-10-20 |  |  |
|  | 01 | **MOVIMIENTO DE TIERRAS** |  | 2023-10-06 | 2023-10-09 |  |  |
| C.70.03.01.11 |  | Excavación manual para instalación de bordillos | 3d | 2023-10-06 | 2023-10-08 | C.90.02.01.12 | 26d |
| C.70.03.01.13 |  | Eliminación material excedente | 4d | 2023-10-06 | 2023-10-09 | C.70.03.01.11 SS | 26d |
| C.70.03.01.12 |  | Excavación para mejoramiento con tierra vegetal | 1d | 2023-10-09 | 2023-10-09 | C.70.03.01.11, C.70.03.01.13 FF | 26d |
|  | 02 | **PAVIMENTOS, RECUBRIMIENTOS Y BORDILLOS** |  | 2023-10-10 | 2023-10-19 |  |  |
| C.70.03.02.11 |  | Piso de gravilla | 2d | 2023-10-10 | 2023-10-11 | C.70.03.01.12 | 26d |
| C.70.03.02.13 |  | Bordillos de piedra de lugar | 5d | 2023-10-12 | 2023-10-16 | C.70.03.02.11 | 26d |
| C.70.03.02.12 |  | Recubrimiento de piedra de lugar | 3d | 2023-10-17 | 2023-10-19 | C.70.03.02.13 | 26d |
|  | 04 | **INSTALACIÓN DE ALCORQUES** |  | 2023-10-20 | 2023-10-20 |  |  |
| C.70.03.03.11 |  | Instalación de alcorques de piedra | 1d | 2023-10-20 | 2023-10-20 | C.70.03.02.12 | 26d |
|  | 05 | **MOBILIARIO Y EQUIPAMIENTO URBANO** |  | 2023-10-21 | 2023-11-03 |  |  |
|  | 01 | **MOBILIARIOS, BARANDAS Y ESCALERAS** |  | 2023-10-21 | 2023-11-03 |  |  |
| C.70.05.01.11 |  | Escalera de concreto sobre enrocado | 2d | 2023-10-21 | 2023-10-22 | C.70.03.03.11 | 26d |
| C.70.05.01.12 |  | Baranda de madera eucalipto con soga | 2d | 2023-10-23 | 2023-10-24 | C.70.05.01.11 | 26d |
| C.70.05.01.13 |  | Tachos de basura | 2d | 2023-10-25 | 2023-10-26 | C.70.05.01.12 | 26d |

| ID | WBS | Task | Duration | Start | Finish | Predecessors | Total float |
| --- | --- | --- | --- | --- | --- | --- | --- |
| C.70.05.01.14 |  | Bancas de concreto | 2d | 2023-10-27 | 2023-10-28 | C.70.05.01.13 | 26d |
| C.70.05.01.15 |  | Postes de iluminación | 2d | 2023-10-29 | 2023-10-30 | C.70.05.01.14 | 26d |
| C.70.05.01.16 |  | Señalética informativa | 2d | 2023-10-31 | 2023-11-01 | C.70.05.01.15 | 26d |
| C.70.05.01.17 |  | Bolardos de Piedra | 2d | 2023-11-02 | 2023-11-03 | C.70.05.01.16, C.90.02.02.12 FF | 26d |
|  | 10 | **CUERPOS DE TERRAPLEN** |  | 2023-05-23 | 2023-10-19 |  |  |
|  | 01 | **DIQUE A3-D-01** |  | 2023-05-28 | 2023-08-08 |  |  |
| C.70.10.01.11 |  | Excavación en terreno natural con equipo | 9d | 2023-05-28 | 2023-06-05 | C.70.01.02.19 SS+1d | 105d |
| C.70.10.01.13 |  | Perfilado y compatación en zona de corte | 8d | 2023-06-06 | 2023-06-13 | C.70.10.01.11 | 109d |
| C.70.10.01.19 |  | Preparación de fundación cuerpo de dique | 12d | 2023-06-06 | 2023-06-17 | C.70.10.01.13 SS | 109d |
| C.70.10.01.14 |  | Conformación de cuerpo de dique | 4d | 2023-06-14 | 2023-06-17 | C.70.10.01.13, C.70.10.01.19 FF | 109d |
| C.70.10.01.12 |  | Excavación de uña con equipo | 4d | 2023-06-18 | 2023-06-21 | C.70.10.01.14 | 109d |
| C.70.10.01.16 |  | Instalación de geotextil no tejido | 36d | 2023-06-22 | 2023-07-27 | C.70.10.01.12 | 109d |
| C.70.10.01.17 |  | Colocación y acomodo de roca en uña | 13d | 2023-06-22 | 2023-07-04 | C.70.10.01.16 SS | 109d |
| C.70.10.01.18 |  | Colocación y acomodo de roca en talud | 29d | 2023-07-05 | 2023-08-02 | C.70.10.01.17 | 109d |
| C.70.10.01.15 |  | Conformación de corona de dique | 6d | 2023-08-03 | 2023-08-08 | C.70.10.01.18, C.70.10.01.16 | 109d |
|  | 02 | **DIQUE A3-D-02** |  | 2023-05-23 | 2023-10-19 |  |  |
|  | 1 | **SECTOR 1** |  | 2023-06-09 | 2023-09-09 |  |  |
| C.70.10.02.1.11 |  | Excavación en terreno natural con equipo | 21d | 2023-06-09 | 2023-06-29 | C.70.01.02.20 | 77d |
| C.70.10.02.1.13 |  | Perfilado y compatación en zona de corte | 7d | 2023-06-30 | 2023-07-06 | C.70.10.02.1.11 | 77d |
| C.70.10.02.1.19 |  | Preparación de fundación cuerpo de dique | 11d | 2023-06-30 | 2023-07-10 | C.70.10.02.1.13 SS | 77d |
| C.70.10.02.1.14 |  | Conformación de cuerpo de dique | 4d | 2023-07-07 | 2023-07-10 | C.70.10.02.1.13, C.70.10.02.1.19 FF | 77d |
| C.70.10.02.1.12 |  | Excavación de uña con equipo | 5d | 2023-07-11 | 2023-07-15 | C.70.10.02.1.14 | 77d |
| C.70.10.02.1.16 |  | Instalación de geotextil no tejido | 32d | 2023-07-16 | 2023-08-16 | C.70.10.02.1.12 | 77d |
| C.70.10.02.1.17 |  | Colocación y acomodo de roca en uña | 18d | 2023-07-16 | 2023-08-02 | C.70.10.02.1.16 SS | 77d |
| C.70.10.02.1.18 |  | Colocación y acomodo de roca en talud | 32d | 2023-08-03 | 2023-09-03 | C.70.10.02.1.17 | 77d |
| C.70.10.02.1.15 |  | Conformación de corona de dique | 6d | 2023-09-04 | 2023-09-09 | C.70.10.02.1.18, C.70.10.02.1.16 | 77d |
|  | 2 | **SECTOR 2** |  | 2023-05-23 | 2023-09-17 |  |  |
| C.70.10.02.2.11 |  | Excavación en terreno natural con equipo | 16d | 2023-05-23 | 2023-06-07 | C.70.01.02.21 SS+1d | 69d |
| C.70.10.02.2.13 |  | Perfilado y compatación en zona de corte | 14d | 2023-06-08 | 2023-06-21 | C.70.10.02.2.11 | 69d |
| C.70.10.02.2.19 |  | Preparación de fundación cuerpo de dique | 19d | 2023-06-08 | 2023-06-26 | C.70.10.02.2.13 SS | 69d |
| C.70.10.02.2.14 |  | Conformación de cuerpo de dique | 5d | 2023-06-22 | 2023-06-26 | C.70.10.02.2.13, C.70.10.02.2.19 FF | 69d |
| C.70.10.02.2.12 |  | Excavación de uña con equipo | 7d | 2023-06-27 | 2023-07-03 | C.70.10.02.2.14 | 69d |
| C.70.10.02.2.16 |  | Instalación de geotextil no tejido | 66d | 2023-07-04 | 2023-09-07 | C.70.10.02.2.12 | 69d |
| C.70.10.02.2.17 |  | Colocación y acomodo de roca en uña | 24d | 2023-07-04 | 2023-07-27 | C.70.10.02.2.16 SS | 69d |
| C.70.10.02.2.18 |  | Colocación y acomodo de roca en talud | 46d | 2023-07-28 | 2023-09-11 | C.70.10.02.2.17 | 69d |
| C.70.10.02.2.15 |  | Conformación de corona de dique | 6d | 2023-09-12 | 2023-09-17 | C.70.10.02.2.18, C.70.10.02.2.16 | 69d |
|  | 3 | **SECTOR 3** |  | 2023-06-25 | 2023-10-19 |  |  |
| C.70.10.02.3.10 |  | Excavación en terreno natural con equipo | 18d | 2023-06-25 | 2023-07-12 | C.70.01.02.22 | 2d |
| C.70.10.02.3.12 |  | Perfilado y compatación en zona de corte | 13d | 2023-07-13 | 2023-07-25 | C.70.10.02.3.10 | 37d |
| C.70.10.02.3.18 |  | Preparación de fundación cuerpo de dique | 17d | 2023-07-13 | 2023-07-29 | C.70.10.02.3.12 SS | 37d |
| C.70.10.02.3.13 |  | Conformación de cuerpo de dique | 4d | 2023-07-26 | 2023-07-29 | C.70.10.02.3.12, C.70.10.02.3.18 FF | 37d |
| C.70.10.02.3.11 |  | Excavación de uña con equipo | 7d | 2023-07-30 | 2023-08-05 | C.70.10.02.3.13 | 37d |
| C.70.10.02.3.15 |  | Instalación de geotextil no tejido | 62d | 2023-08-06 | 2023-10-06 | C.70.10.02.3.11 | 37d |
| C.70.10.02.3.16 |  | Colocación y acomodo de roca en uña | 26d | 2023-08-06 | 2023-08-31 | C.70.10.02.3.15 SS | 37d |
| C.70.10.02.3.17 |  | Colocación y acomodo de roca en talud | 43d | 2023-09-01 | 2023-10-13 | C.70.10.02.3.16, C.90.02.07.13 FF, C.90.02.07.14 | 37d |
| C.70.10.02.3.14 |  | Conformación de corona de dique | 6d | 2023-10-14 | 2023-10-19 | C.70.10.02.3.17, C.70.10.02.3.15, C.90.02.07.12 FF, C.90.02.07.11 FF | 37d |
|  | 03 | **DIQUE A3-I-01** |  | 2023-07-05 | 2023-09-27 |  |  |
| C.70.10.03.11 |  | Excavación en terreno natural con equipo | 18d | 2023-07-05 | 2023-07-22 | C.70.01.02.23 | 58d |
| C.70.10.03.13 |  | Perfilado y compatación en zona de corte | 7d | 2023-07-23 | 2023-07-29 | C.70.10.03.11 | 59d |
| C.70.10.03.19 |  | Preparación de fundación cuerpo de dique | 16d | 2023-07-23 | 2023-08-07 | C.70.10.03.13 SS | 59d |
| C.70.10.03.14 |  | Conformación de cuerpo de dique | 9d | 2023-07-30 | 2023-08-07 | C.70.10.03.13, C.70.10.03.19 FF | 59d |
| C.70.10.03.12 |  | Excavación de uña con equipo | 4d | 2023-08-08 | 2023-08-11 | C.70.10.03.14, C.90.02.07.16 FF, C.90.02.07.15 FF | 59d |
| C.70.10.03.16 |  | Instalación de geotextil no tejido | 35d | 2023-08-12 | 2023-09-15 | C.70.10.03.12 | 59d |
| C.70.10.03.17 |  | Colocación y acomodo de roca en uña | 13d | 2023-08-12 | 2023-08-24 | C.70.10.03.16 SS | 59d |
| C.70.10.03.18 |  | Colocación y acomodo de roca en talud | 28d | 2023-08-25 | 2023-09-21 | C.70.10.03.17 | 59d |
| C.70.10.03.15 |  | Conformación de corona de dique | 6d | 2023-09-22 | 2023-09-27 | C.70.10.03.18, C.70.10.03.16 | 59d |
|  | 04 | **DIQUE A3-I-02** |  | 2023-06-20 | 2023-09-21 |  |  |
| C.70.10.04.11 |  | Excavación en terreno natural con equipo | 25d | 2023-06-20 | 2023-07-14 | C.70.01.02.24 | 0d |
| C.70.10.04.13 |  | Perfilado y compatación en zona de corte | 8d | 2023-07-15 | 2023-07-22 | C.70.10.04.11 | 26d |
| C.70.10.04.19 |  | Preparación de fundación cuerpo de dique | 8d | 2023-07-15 | 2023-07-22 | C.70.10.04.13 SS | 26d |
| C.70.10.04.12 |  | Excavación de uña con equipo | 5d | 2023-07-23 | 2023-07-27 | C.70.10.04.14 | 26d |
| C.70.10.04.14 |  | Conformación de cuerpo de dique | 0d | 2023-07-23 | 2023-07-23 | C.70.10.04.13, C.70.10.04.19 FF | 26d |
| C.70.10.04.16 |  | Instalación de geotextil no tejido | 31d | 2023-07-28 | 2023-08-27 | C.70.10.04.12 | 26d |
| C.70.10.04.17 |  | Colocación y acomodo de roca en uña | 17d | 2023-07-28 | 2023-08-13 | C.70.10.04.16 SS | 26d |
| C.70.10.04.18 |  | Colocación y acomodo de roca en talud | 32d | 2023-08-14 | 2023-09-14 | C.70.10.04.17 | 26d |
| C.70.10.04.15 |  | Conformación de corona de dique | 7d | 2023-09-15 | 2023-09-21 | C.70.10.04.18, C.70.10.04.16 | 26d |
|  | 05 | **DIQUE A3-I-03** |  | 2023-06-17 | 2023-10-18 |  |  |
|  | 1 | **SECTOR 1** |  | 2023-06-17 | 2023-10-08 |  |  |
| C.70.10.05.1.11 |  | Excavación en terreno natural con equipo | 16d | 2023-06-17 | 2023-07-02 | C.70.01.02.25 | 48d |
| C.70.10.05.1.13 |  | Perfilado y compatación en zona de corte | 12d | 2023-07-03 | 2023-07-14 | C.70.10.05.1.11 | 48d |

| ID | WBS | Task | Duration | Start | Finish | Predecessors | Total float |
| --- | --- | --- | --- | --- | --- | --- | --- |
| C.70.10.05.1.19 |  | Preparación de fundación cuerpo de dique | 14d | 2023-07-03 | 2023-07-16 | C.70.10.05.1.13 SS | 48d |
| C.70.10.05.1.14 |  | Conformación de cuerpo de dique | 2d | 2023-07-15 | 2023-07-16 | C.70.10.05.1.13, C.70.10.05.1.19 FF | 48d |
| C.70.10.05.1.12 |  | Excavación de uña con equipo | 7d | 2023-07-17 | 2023-07-23 | C.70.10.05.1.14 | 48d |
| C.70.10.05.1.16 |  | Instalación de geotextil no tejido | 66d | 2023-07-24 | 2023-09-27 | C.70.10.05.1.12 | 48d |
| C.70.10.05.1.17 |  | Colocación y acomodo de roca en uña | 24d | 2023-07-24 | 2023-08-16 | C.70.10.05.1.16 SS | 48d |
| C.70.10.05.1.18 |  | Colocación y acomodo de roca en talud | 47d | 2023-08-17 | 2023-10-02 | C.70.10.05.1.17 | 48d |
| C.70.10.05.1.15 |  | Conformación de corona de dique | 6d | 2023-10-03 | 2023-10-08 | C.70.10.05.1.18 | 48d |
|  | 2 | **SECTOR 2** |  | 2023-06-21 | 2023-10-18 |  |  |
| C.70.10.05.2.11 |  | Excavación en terreno natural con equipo | 15d | 2023-06-21 | 2023-07-05 | C.70.01.02.26 | 38d |
| C.70.10.05.2.13 |  | Perfilado y compatación en zona de corte | 13d | 2023-07-06 | 2023-07-18 | C.70.10.05.2.11 | 38d |
| C.70.10.05.2.19 |  | Preparación de fundación cuerpo de dique | 20d | 2023-07-06 | 2023-07-25 | C.70.10.05.2.13 SS | 38d |
| C.70.10.05.2.14 |  | Conformación de cuerpo de dique | 7d | 2023-07-19 | 2023-07-25 | C.70.10.05.2.13, C.70.10.05.2.19 FF | 38d |
| C.70.10.05.2.12 |  | Excavación de uña con equipo | 8d | 2023-07-26 | 2023-08-02 | C.70.10.05.2.14 | 38d |
| C.70.10.05.2.16 |  | Instalación de geotextil no tejido | 64d | 2023-08-03 | 2023-10-05 | C.70.10.05.2.12 | 38d |
| C.70.10.05.2.17 |  | Colocación y acomodo de roca en uña | 27d | 2023-08-03 | 2023-08-29 | C.70.10.05.2.16 SS | 38d |
| C.70.10.05.2.18 |  | Colocación y acomodo de roca en talud | 44d | 2023-08-30 | 2023-10-12 | C.70.10.05.2.17 | 38d |
| C.70.10.05.2.15 |  | Conformación de corona de dique | 6d | 2023-10-13 | 2023-10-18 | C.70.10.05.2.18 | 38d |
|  | 11 | **SUPERFICIES DE TERRAPLEN** |  | 2023-06-27 | 2023-07-28 |  |  |
|  | 01 | **RAMPA A3-RA-D-01** |  | 2023-06-27 | 2023-06-29 |  |  |
| C.70.11.01.11 |  | Excavación en terreno natural con equipo | 1d | 2023-06-27 | 2023-06-27 | C.70.10.02.2.14 | 149d |
| C.70.11.01.12 |  | Conformación de cuerpo de dique | 0d | 2023-06-28 | 2023-06-28 | C.70.11.01.11 | 149d |
| C.70.11.01.13 |  | Conformación de coronación de rampas | 2d | 2023-06-28 | 2023-06-29 | C.70.11.01.12 | 149d |
|  | 02 | **RAMPA A3-RA-I-01** |  | 2023-07-26 | 2023-07-28 |  |  |
| C.70.11.02.11 |  | Excavación en terreno natural con equipo | 1d | 2023-07-26 | 2023-07-26 | C.70.10.05.2.14 | 120d |
| C.70.11.02.12 |  | Conformación de cuerpo de dique | 0d | 2023-07-27 | 2023-07-27 | C.70.11.02.11 | 120d |
| C.70.11.02.13 |  | Conformación de coronación de rampas | 2d | 2023-07-27 | 2023-07-28 | C.70.11.02.12 | 120d |
|  | 60 | **TRABAJOS DE RENOVACIÓN** |  | 2023-07-05 | 2023-11-25 |  |  |
|  | 02 | **REPARACION DE SERVICIOS EXISTENTES** |  | 2023-07-05 | 2023-11-25 |  |  |
|  | 01 | **REPOSICION CANAL 1** |  | 2023-07-15 | 2023-11-25 |  |  |
|  | 01 | **MOVIMIENTO DE TIERRAS** |  | 2023-07-15 | 2023-11-25 |  |  |
| C.60.02.01.01.11 |  | Excavación en terreno natural con equipo | 10d | 2023-07-15 | 2023-07-24 | C.80.02.14, C.70.10.02.3.10, C.70.10.04.11 | 0d |
| C.60.02.01.01.12 |  | Relleno estructural para obras de arte con material propio | 51d | 2023-10-06 | 2023-11-25 | C.60.02.01.02.17 | 0d |
|  | 02 | **OBRAS DE CONCRETO** |  | 2023-07-25 | 2023-10-06 |  |  |
| C.60.02.01.02.13 |  | Concreto - solado | 6d | 2023-07-25 | 2023-07-30 | C.60.02.01.01.11 | 0d |
| C.60.02.01.02.12 |  | Acero de refuerzo | 20d | 2023-07-31 | 2023-08-19 | C.60.02.01.02.13 | 0d |
| C.60.02.01.02.15 |  | Junta Water Stop | 37d | 2023-07-31 | 2023-09-05 | C.60.02.01.02.12 SS | 0d |
| C.60.02.01.02.11 |  | Encofrado recto | 17d | 2023-08-20 | 2023-09-05 | C.60.02.01.02.12, C.60.02.01.02.15 FF | 0d |
| C.60.02.01.02.14 |  | Concreto canal | 13d | 2023-09-06 | 2023-09-18 | C.60.02.01.02.11 | 0d |
| C.60.02.01.02.17 |  | Desencofrado | 17d | 2023-09-19 | 2023-10-05 | C.60.02.01.02.14 | 0d |
| C.60.02.01.02.16 |  | Mamposteria de piedra | 1d | 2023-10-06 | 2023-10-06 | C.60.02.01.02.17 | 50d |
|  | 02 | **REPOSICION CANAL 3** |  | 2023-07-23 | 2023-08-15 |  |  |
|  | 01 | **MOVMIENTO DE TIERRAS** |  | 2023-07-23 | 2023-08-15 |  |  |
| C.60.02.02.01.11 |  | Excavación en terreno natural con equipo | 1d | 2023-07-23 | 2023-07-23 | C.80.02.15, C.70.10.01.11, C.70.10.03.11 | 102d |
| C.60.02.02.01.12 |  | Relleno estructural para obras de arte con material propio | 2d | 2023-08-14 | 2023-08-15 | C.60.02.02.02.17 | 102d |
|  | 02 | **OBRAS DE CONCRETO** |  | 2023-07-24 | 2023-08-14 |  |  |
| C.60.02.02.02.13 |  | Concreto - solado | 2d | 2023-07-24 | 2023-07-25 | C.60.02.02.01.11 | 102d |
| C.60.02.02.02.12 |  | Malla Electrosoldada | 9d | 2023-07-26 | 2023-08-03 | C.60.02.02.02.13 | 102d |
| C.60.02.02.02.15 |  | Junta Water Stop | 13d | 2023-07-26 | 2023-08-07 | C.60.02.02.02.12 SS | 102d |
| C.60.02.02.02.11 |  | Encofrado recto | 4d | 2023-08-04 | 2023-08-07 | C.60.02.02.02.12, C.60.02.02.02.15 FF | 102d |
| C.60.02.02.02.14 |  | Concreto canal | 2d | 2023-08-08 | 2023-08-09 | C.60.02.02.02.11 | 102d |
| C.60.02.02.02.17 |  | Desencofrado | 4d | 2023-08-10 | 2023-08-13 | C.60.02.02.02.14 | 102d |
| C.60.02.02.02.16 |  | Mamposteria de piedra | 1d | 2023-08-14 | 2023-08-14 | C.60.02.02.02.17 | 103d |
|  | 03 | **REPOSICION SIFON INOPERATIVO** |  | 2023-07-05 | 2023-08-03 |  |  |
| C.60.02.03.11 |  | Excavación estructural para obras de arte | 14d | 2023-07-05 | 2023-07-18 | C.80.02.16, C.70.10.01.11 SS, C.70.10.03.11 SS | 115d |
| C.60.02.03.12 |  | Colocación de cama de arena | 1d | 2023-07-19 | 2023-07-19 | C.60.02.03.11 | 115d |
| C.60.02.03.15 |  | Tuberias HDPE | 2d | 2023-07-20 | 2023-07-21 | C.60.02.03.12 | 115d |
| C.60.02.03.21 |  | Codos HDPE | 2d | 2023-07-22 | 2023-07-23 | C.60.02.03.15 | 115d |
| C.60.02.03.14 |  | Relleno comun | 5d | 2023-07-24 | 2023-07-28 | C.60.02.03.21 | 115d |
| C.60.02.03.16 |  | Concreto - Solado | 1d | 2023-07-29 | 2023-07-29 | C.60.02.03.14 | 115d |
| C.60.02.03.20 |  | Acero de refuerzo | 1d | 2023-07-30 | 2023-07-30 | C.60.02.03.16 | 115d |
| C.60.02.03.18 |  | Encofrado | 1d | 2023-07-31 | 2023-07-31 | C.60.02.03.20 | 115d |
| C.60.02.03.17 |  | Concreto | 1d | 2023-08-01 | 2023-08-01 | C.60.02.03.18 | 115d |
| C.60.02.03.19 |  | Desencofrado | 1d | 2023-08-02 | 2023-08-02 | C.60.02.03.17 | 115d |
| C.60.02.03.13 |  | Rellno estructural para obras de arte con material propio | 0d | 2023-08-03 | 2023-08-03 | C.60.02.03.19 | 115d |
|  | 21 | **REGISTROS Y CAMARAS** |  | 2023-07-06 | 2023-09-28 |  |  |
|  | 01 | **CAPTACION A3-CP-23-95** |  | 2023-07-06 | 2023-09-14 |  |  |
|  | 01 | **MOVIMIENTO DE TIERRAS** |  | 2023-07-24 | 2023-09-12 |  |  |
| C.21.01.01.11 |  | Excavación estructural para obras de arte | 8d | 2023-07-24 | 2023-07-31 | C.21.01.04.11 SS | 90d |
| C.21.01.01.12 |  | Relleno estructural para obras de arte con material propio | 3d | 2023-09-10 | 2023-09-12 | C.21.01.02.13, C.21.01.04.13 SS, C.21.01.05.12 SS, C.21.01.06.12 SS | 74d |
|  | 02 | **OBRAS DE CONCRETO** |  | 2023-08-01 | 2023-08-27 |  |  |

| ID | WBS | Task | Duration | Start | Finish | Predecessors | Total float |
| --- | --- | --- | --- | --- | --- | --- | --- |
| C.21.01.02.11 |  | Concreto - solado | 1d | 2023-08-01 | 2023-08-01 | C.21.01.01.11 | 90d |
| C.21.01.02.16 |  | Acero de refuerzo | 9d | 2023-08-02 | 2023-08-10 | C.21.01.02.11 | 90d |
| C.21.01.02.14 |  | Encofrado | 5d | 2023-08-11 | 2023-08-15 | C.21.01.02.16 | 90d |
| C.21.01.02.12 |  | Concreto - muro | 6d | 2023-08-16 | 2023-08-21 | C.21.01.02.14 | 90d |
| C.21.01.02.13 |  | Concreto Ciclopeo | 1d | 2023-08-22 | 2023-08-22 | C.21.01.02.12 | 90d |
| C.21.01.02.15 |  | Desencofrado | 5d | 2023-08-23 | 2023-08-27 | C.21.01.02.13 | 90d |
|  | 03 | **ESTRUCTURAS METALICAS** |  | 2023-08-02 | 2023-08-10 |  |  |
| C.21.01.03.11 |  | Compuerta metalica | 0d | 2023-08-02 | 2023-08-02 | C.21.01.06.19 | 107d |
| C.21.01.03.12 |  | Rejilla | 1d | 2023-08-02 | 2023-08-02 | C.21.01.03.11 | 107d |
| C.21.01.03.13 |  | Baranda de fierro galvanizado | 1d | 2023-08-03 | 2023-08-03 | C.21.01.03.12 | 107d |
| C.21.01.03.14 |  | Escalera tipo gato | 1d | 2023-08-04 | 2023-08-04 | C.21.01.03.13 | 107d |
| C.21.01.03.15 |  | Tapa metálica | 6d | 2023-08-05 | 2023-08-10 | C.21.01.03.14 | 107d |
|  | 04 | **TUBERIA** |  | 2023-07-06 | 2023-08-09 |  |  |
| C.21.01.04.12 |  | Excavación de zanja | 8d | 2023-07-06 | 2023-07-13 | C.70.10.05.2.11, C.70.10.02.2.11 | 74d |
| C.21.01.04.14 |  | Cama de arena | 2d | 2023-07-14 | 2023-07-15 | C.21.01.04.12 | 74d |
| C.21.01.04.23 |  | Instalación tubería | 2d | 2023-07-16 | 2023-07-17 | C.21.01.04.14 | 74d |
| C.21.01.04.15 |  | Relleno común para zanjas | 6d | 2023-07-18 | 2023-07-23 | C.21.01.04.23 | 74d |
| C.21.01.04.11 |  | Excavación estructural para obras de arte | 3d | 2023-07-24 | 2023-07-26 | C.21.01.04.15 | 74d |
| C.21.01.04.16 |  | Concreto solado - Buzones | 1d | 2023-07-27 | 2023-07-27 | C.21.01.04.11 | 108d |
| C.21.01.04.20 |  | Acero de refuerzo | 3d | 2023-07-28 | 2023-07-30 | C.21.01.04.16 | 108d |
| C.21.01.04.18 |  | Encofrado recto | 1d | 2023-07-31 | 2023-07-31 | C.21.01.04.20 | 110d |
| C.21.01.04.19 |  | Encofrado curvo | 3d | 2023-07-31 | 2023-08-02 | C.21.01.04.20 | 108d |
| C.21.01.04.17 |  | Concreto - Buzones | 1d | 2023-08-03 | 2023-08-03 | C.21.01.04.18, C.21.01.04.19 | 108d |
| C.21.01.04.21 |  | Desencofrado recto | 1d | 2023-08-04 | 2023-08-04 | C.21.01.04.17 | 110d |
| C.21.01.04.22 |  | Desencodrado curvo | 3d | 2023-08-04 | 2023-08-06 | C.21.01.04.17 | 108d |
| C.21.01.04.13 |  | Relleno estructural para obras de arte con material propio | 3d | 2023-08-07 | 2023-08-09 | C.21.01.04.21, C.21.01.04.22 | 108d |
|  | 05 | **CANALES** |  | 2023-07-24 | 2023-09-14 |  |  |
| C.21.01.05.11 |  | Excavación estructural para obras de arte | 4d | 2023-07-24 | 2023-07-27 | C.21.01.04.11 SS | 74d |
| C.21.01.05.13 |  | Colocación solado | 2d | 2023-07-28 | 2023-07-29 | C.21.01.05.11 | 74d |
| C.21.01.05.16 |  | Acero de refuerzo | 10d | 2023-07-30 | 2023-08-08 | C.21.01.05.13 | 74d |
| C.21.01.05.18 |  | Junta Water Stop | 22d | 2023-07-30 | 2023-08-20 | C.21.01.05.16 SS | 74d |
| C.21.01.05.15 |  | Encofrado | 12d | 2023-08-09 | 2023-08-20 | C.21.01.05.16, C.21.01.05.18 FF | 74d |
| C.21.01.05.14 |  | Colocación concreto | 8d | 2023-08-21 | 2023-08-28 | C.21.01.05.15 | 74d |
| C.21.01.05.17 |  | Desencofrado | 12d | 2023-08-29 | 2023-09-09 | C.21.01.05.14 | 74d |
| C.21.01.05.12 |  | Relleno estructural para canales | 5d | 2023-09-10 | 2023-09-14 | C.21.01.05.17 | 74d |
|  | 06 | **OBRAS DE DESCARGA** |  | 2023-07-24 | 2023-08-06 |  |  |
| C.21.01.06.11 |  | Excavación estructural para obras de arte | 1d | 2023-07-24 | 2023-07-24 | C.21.01.04.11 SS | 107d |
| C.21.01.06.13 |  | Concreto - solado | 1d | 2023-07-25 | 2023-07-25 | C.21.01.06.11 | 107d |
| C.21.01.06.17 |  | Acero de refuerzo | 1d | 2023-07-26 | 2023-07-26 | C.21.01.06.13 | 107d |
| C.21.01.06.18 |  | Junta Water Stop | 3d | 2023-07-26 | 2023-07-28 | C.21.01.06.17 SS | 107d |
| C.21.01.06.15 |  | Encofrado recto | 2d | 2023-07-27 | 2023-07-28 | C.21.01.06.17, C.21.01.06.18 FF | 107d |
| C.21.01.06.14 |  | Concreto canal | 1d | 2023-07-29 | 2023-07-29 | C.21.01.06.15 | 107d |
| C.21.01.06.16 |  | Desencofrado | 2d | 2023-07-30 | 2023-07-31 | C.21.01.06.14 | 114d |
| C.21.01.06.19 |  | Compuerta metalica | 3d | 2023-07-30 | 2023-08-01 | C.21.01.06.14 | 107d |
| C.21.01.06.12 |  | Relleno estructural para obras de arte con material propio | 6d | 2023-08-01 | 2023-08-06 | C.21.01.06.16 | 114d |
|  | 02 | **CAPTACION A3-CP-21-05** |  | 2023-07-23 | 2023-09-03 |  |  |
|  | 01 | **MOVIMIENTO DE TIERRAS** |  | 2023-07-28 | 2023-08-19 |  |  |
| C.21.02.01.11 |  | Excavación estructural para obras de arte | 5d | 2023-07-28 | 2023-08-01 | C.21.02.04.15 | 83d |
| C.21.02.01.12 |  | Relleno estructural para obras de arte con material propio | 1d | 2023-08-19 | 2023-08-19 | C.21.02.05.12 SS | 98d |
|  | 02 | **OBRAS DE CONCRETO** |  | 2023-08-02 | 2023-08-25 |  |  |
| C.21.02.02.11 |  | Concreto - solado | 1d | 2023-08-02 | 2023-08-02 | C.21.02.01.11 | 83d |
| C.21.02.02.16 |  | Acero de refuerzo | 7d | 2023-08-03 | 2023-08-09 | C.21.02.02.11 | 83d |
| C.21.02.02.14 |  | Encofrado | 5d | 2023-08-10 | 2023-08-14 | C.21.02.02.16 | 83d |
| C.21.02.02.12 |  | Concreto - muro | 6d | 2023-08-15 | 2023-08-20 | C.21.02.02.14 | 83d |
| C.21.02.02.13 |  | Concreto Ciclopeo | 1d | 2023-08-15 | 2023-08-15 | C.21.02.02.14 | 88d |
| C.21.02.02.15 |  | Desencofrado | 5d | 2023-08-21 | 2023-08-25 | C.21.02.02.12, C.21.02.02.13 | 83d |
|  | 03 | **ESTRUCTURAS METALICAS** |  | 2023-08-26 | 2023-09-03 |  |  |
| C.21.02.03.11 |  | Compuerta metalica | 4d | 2023-08-26 | 2023-08-29 | C.21.02.02.15 | 83d |
| C.21.02.03.12 |  | Rejilla | 1d | 2023-08-30 | 2023-08-30 | C.21.02.03.11 | 83d |
| C.21.02.03.13 |  | Baranda de fierro galvanizado | 1d | 2023-08-31 | 2023-08-31 | C.21.02.03.12 | 83d |
| C.21.02.03.14 |  | Escalera tipo gato | 1d | 2023-09-01 | 2023-09-01 | C.21.02.03.13 | 83d |
| C.21.02.03.15 |  | Tapa metálica | 2d | 2023-09-02 | 2023-09-03 | C.21.02.03.14 | 83d |
|  | 04 | **TUBERÍA** |  | 2023-07-23 | 2023-08-06 |  |  |
| C.21.02.04.12 |  | Excavación de zanja | 1d | 2023-07-23 | 2023-07-23 | C.70.10.03.11, C.70.10.01.11 | 83d |
| C.21.02.04.14 |  | Cama de arena | 1d | 2023-07-24 | 2023-07-24 | C.21.02.04.12 | 83d |
| C.21.02.04.23 |  | Instalación tubería | 1d | 2023-07-25 | 2023-07-25 | C.21.02.04.14 | 83d |
| C.21.02.04.15 |  | Relleno común para zanjas | 2d | 2023-07-26 | 2023-07-27 | C.21.02.04.23 | 83d |
| C.21.02.04.11 |  | Excavación estructural para obras de arte | 1d | 2023-07-28 | 2023-07-28 | C.21.02.04.15 | 111d |
| C.21.02.04.16 |  | Concreto solado - Buzones | 1d | 2023-07-29 | 2023-07-29 | C.21.02.04.11 | 111d |
| C.21.02.04.20 |  | Acero de refuerzo | 2d | 2023-07-30 | 2023-07-31 | C.21.02.04.16 | 111d |

| ID | WBS | Task | Duration | Start | Finish | Predecessors | Total float |
| --- | --- | --- | --- | --- | --- | --- | --- |
| C.21.02.04.18 |  | Encofrado recto | 1d | 2023-08-01 | 2023-08-01 | C.21.02.04.20 | 112d |
| C.21.02.04.19 |  | Encofrado curvo | 2d | 2023-08-01 | 2023-08-02 | C.21.02.04.20 | 111d |
| C.21.02.04.17 |  | Concreto - Buzones | 1d | 2023-08-03 | 2023-08-03 | C.21.02.04.18, C.21.02.04.19 | 111d |
| C.21.02.04.21 |  | Desencofrado recto | 1d | 2023-08-04 | 2023-08-04 | C.21.02.04.17 | 112d |
| C.21.02.04.22 |  | Desencodrado curvo | 2d | 2023-08-04 | 2023-08-05 | C.21.02.04.17 | 111d |
| C.21.02.04.13 |  | Relleno estructural para obras de arte con material propio | 1d | 2023-08-06 | 2023-08-06 | C.21.02.04.21, C.21.02.04.22 | 111d |
|  | 05 | **CANALES** |  | 2023-07-28 | 2023-08-25 |  |  |
| C.21.02.05.11 |  | Excavación estructural para obras de arte | 7d | 2023-07-28 | 2023-08-03 | C.21.02.04.15 | 98d |
| C.21.02.05.13 |  | Colocación solado | 1d | 2023-08-04 | 2023-08-04 | C.21.02.05.11 | 98d |
| C.21.02.05.16 |  | Acero de refuerzo | 3d | 2023-08-05 | 2023-08-07 | C.21.02.05.13 | 98d |
| C.21.02.05.18 |  | Junta Water Stop | 7d | 2023-08-05 | 2023-08-11 | C.21.02.05.16 SS | 98d |
| C.21.02.05.15 |  | Encofrado | 4d | 2023-08-08 | 2023-08-11 | C.21.02.05.16, C.21.02.05.18 FF | 98d |
| C.21.02.05.14 |  | Colocación concreto | 3d | 2023-08-12 | 2023-08-14 | C.21.02.05.15 | 98d |
| C.21.02.05.17 |  | Desencofrado | 4d | 2023-08-15 | 2023-08-18 | C.21.02.05.14 | 98d |
| C.21.02.05.12 |  | Relleno estructural para canales | 7d | 2023-08-19 | 2023-08-25 | C.21.02.05.17 | 98d |
|  | 03 | **RETORNO A3-OA-RE-D-21-55** |  | 2023-07-23 | 2023-09-28 |  |  |
|  | 01 | **MOVIMIENTO DE TIERRAS** |  | 2023-07-23 | 2023-09-25 |  |  |
| C.21.03.01.11 |  | Excavación estructural para obras de arte | 1d | 2023-07-23 | 2023-07-23 | C.70.10.01.11, C.70.10.03.11 | 58d |
| C.21.03.01.12 |  | Relleno estructural para obras de arte con material propio | 0d | 2023-09-25 | 2023-09-25 | C.21.03.02.17 | 62d |
|  | 02 | **OBRAS DE CONCRETO** |  | 2023-07-24 | 2023-09-24 |  |  |
| C.21.03.02.11 |  | Concreto - solado | 1d | 2023-07-24 | 2023-07-24 | C.21.03.01.11 | 58d |
| C.21.03.02.15 |  | Acero de refuerzo | 46d | 2023-07-25 | 2023-09-08 | C.21.03.02.11 | 58d |
| C.21.03.02.16 |  | Junta Water Stop | 52d | 2023-07-25 | 2023-09-14 | C.21.03.02.15 SS | 58d |
| C.21.03.02.14 |  | Encofrado | 6d | 2023-09-09 | 2023-09-14 | C.21.03.02.15, C.21.03.02.16 FF | 58d |
| C.21.03.02.12 |  | Concreto | 2d | 2023-09-15 | 2023-09-16 | C.21.03.02.14 | 60d |
| C.21.03.02.13 |  | Concreto Ciclopeo | 4d | 2023-09-15 | 2023-09-18 | C.21.03.02.14 | 58d |
| C.21.03.02.17 |  | Desencofrado | 6d | 2023-09-19 | 2023-09-24 | C.21.03.02.12, C.21.03.02.13 | 58d |
|  | 03 | **ESTRUCTURAS METALICAS** |  | 2023-09-25 | 2023-09-28 |  |  |
| C.21.03.03.11 |  | Compuerta metalica plana | 4d | 2023-09-25 | 2023-09-28 | C.21.03.02.17 | 58d |
| C.21.03.03.12 |  | Baranda de fierro galvanizado | 1d | 2023-09-25 | 2023-09-25 | C.21.03.02.17 | 61d |
|  | T | **CIERRE** |  | 2023-11-26 | 2023-12-02 |  |  |
|  | 20 | **DESMOVILIZACIÓN** |  | 2023-11-26 | 2023-12-02 |  |  |
| T.20.11 |  | Desmovilización equipos | 4d | 2023-11-26 | 2023-11-29 | C.90.02.04.13, C.70.02.01.03.16, C.70.02.01.03.13, C.70.02.01.02.01.11, C.70.02.01.02.02.11, C.70.02.01.01.11, C.70.02.01.01.14, C.70.02.01.01.13, C.70.02.01.01.12, C.70.10.01.15, C.70.10.02.1.15, C.70.10.02.2.15, C.70.10.02.3.14, C.70.10.03.15, C.70.10.04.15, C.70.10.05.1.15, C.70.10.05.2.15, C.70.11.01.13, C.70.11.02.13, C.60.02.01.02.16, C.60.02.02.02.16, C.60.02.03.13, C.21.01.03.15, C.21.02.03.15, C.21.03.03.12, C.21.03.03.11, C.21.03.01.12, C.60.02.01.01.12, C.60.02.02.01.12, C.21.01.01.12, C.21.01.02.15, C.21.02.01.12, C.21.02.04.13 | 0d |
| T.20.12 |  | Desmovilización equipos - Paisajismo | 3d | 2023-11-30 | 2023-12-02 | T.20.11, C.70.03.03.11, C.70.05.01.17 | 0d |

## Version 2 (data date 2023-05-02, saved 2023-05-03, file Cronograma oferta_B.xer)

Last finish stays 2023-12-02.

Added:

| ID | Task | Duration | Start | Finish | Predecessors | Constraint | Resources |
| --- | --- | --- | --- | --- | --- | --- | --- |
| C.80.02.23.1 | Conformación de desvió en cauce de río Dique A3-I-03 - Sector 1 - Tramo 1 | 5d | 2023-06-22 | 2023-06-26 | C.70.01.01.18.1 |  | HH [138.1 h]; HM [65.93 h] |
| C.80.02.21.1 | Conformación de desvió en cauce de río Dique A3-I-01 - Tramo 1 | 3d | 2023-06-23 | 2023-06-25 | C.70.01.01.16.1 |  | HH [72.46 h]; HM [34.59 h] |
| C.70.01.01.18.1 | Desbroce y limpieza Dique A3-I-03 - Sector 1 - Tramo 1 | 31d | 2023-05-22 | 2023-06-21 | C.70.02.01.01.11 |  | HH [3277.66 h]; HM [1015.57 h] |
| C.70.01.01.16.1 | Desbroce y limpieza Dique A3-I-01 - Tramo 1 | 30d | 2023-05-24 | 2023-06-22 | C.70.02.01.01.14 |  | HH [6495.4 h]; HM [2012.57 h] |
| C.70.01.02.15.1 | Descolmatación Dique A3-I-01 - Tramo 1 | 21d | 2023-06-26 | 2023-07-16 | C.80.02.21.1 |  | HH [883.18 h]; HM [569.96 h] |
| C.70.01.02.17.1 | Descolmatación Dique A3-I-03 - Sector 1 - Tramo 1 | 11d | 2023-06-27 | 2023-07-07 | C.80.02.23.1 |  | HH [445.67 h]; HM [287.61 h] |
| C.70.01.02.25.1 | Relleno no estructural Dique A3-I-03 - Sector 1 - Tramo 1 | 5d | 2023-07-08 | 2023-07-12 | C.70.01.02.17.1 |  | HH [138.1 h]; HM [65.93 h] |
| C.70.01.02.23.1 | Relleno no estructural Dique A3-I-01- Tramo 1 | 3d | 2023-07-17 | 2023-07-19 | C.70.01.02.15.1 |  | HH [72.46 h]; HM [34.59 h] |
| 1 | **Tramo 1 (PK 20+960 - 21+300)** |  | 2023-09-30 | 2023-11-15 |  |  |  |
| C.70.10.03.20 | Excavación en terreno natural con equipo | 8d | 2023-09-30 | 2023-10-07 | C.70.10.03.11, C.70.10.05.1.21 | as late as possible | EXCAVACIONES [3244.4]; HH [168.06 h]; HM [108.36 h] |
| C.70.10.03.22 | Perfilado y compatación en zona de corte | 5d | 2023-10-08 | 2023-10-12 | C.70.10.03.20, C.70.10.03.13 | as late as possible | HH [182.07 h]; HM [82.7 h] |
| C.70.10.03.28 | Preparación de fundación cuerpo de dique | 14d | 2023-10-08 | 2023-10-21 | C.70.10.03.22 SS |  | HH [37.31 h]; HM [18.72 h] |
| C.70.10.03.23 | Conformación de cuerpo de dique | 9d | 2023-10-13 | 2023-10-21 | C.70.10.03.22, C.70.10.03.28 FF, C.70.10.03.14 | as late as possible | RELLENOS [306.57]; HH [2322.5 h]; HM [478.9 h] |
| C.70.10.03.21 | Excavación de uña con equipo | 3d | 2023-10-22 | 2023-10-24 | C.70.10.03.23, C.70.10.03.12, C.90.02.07.15 FF, C.90.02.07.16 FF | as late as possible | EXCAVACIONES [880]; HH [54.56 h]; HM [52.8 h] |
| C.70.10.03.25 | Instlación de geotextil no tejido | 15d | 2023-10-25 | 2023-11-08 | C.70.10.03.21, C.70.10.03.16, C.70.10.05.1.25 | as late as possible | HH [177.17 h] |
| C.70.10.03.26 | Colocación y acomodo de roca en uña | 6d | 2023-10-25 | 2023-10-30 | C.70.10.03.25 SS, C.70.10.03.17, C.70.10.05.1.27 | as late as possible | ENROCADOS [880]; HH [388.61 h]; HM [161.3 h] |
| C.70.10.03.27 | Colocaicón y acomodo de roca en talud | 14d | 2023-10-31 | 2023-11-13 | C.70.10.03.26, C.70.10.03.25 FF, C.70.10.03.18, C.90.02.07.13 FF, C.90.02.07.14 FF | as late as possible | ENROCADOS [1525.5]; HH [934.37 h]; HM [343.24 h] |
| C.70.10.03.24 | Conformación de corona de dique | 2d | 2023-11-14 | 2023-11-15 | C.70.10.03.27, C.70.10.03.25, C.70.10.03.15, C.70.10.05.1.24, C.90.02.07.11 FF, C.90.02.07.12 FF | as late as possible | HH [123.99 h]; HM [62.64 h] |
| 2 | **Tramo 2 (PK 21+300 - 21+805)** |  | 2023-07-20 | 2023-09-28 |  |  |  |
| 1 | **Tramo 1 (PK 22+750 - 23+760)** |  | 2023-07-13 | 2023-10-09 |  |  |  |
| 2 | **Tramo 2 (PK 23+760 - 24+350)** |  | 2023-09-08 | 2023-10-25 |  |  |  |
| C.70.10.05.1.20 | Excavación en terreno natural con equipo | 5d | 2023-09-08 | 2023-09-12 | C.70.10.05.1.11 | as late as possible | EXCAVACIONES [5525.6]; HH [286.23 h]; HM [184.56 h] |
| C.70.10.05.1.22 | Perfilado y compactación en zona de corte | 7d | 2023-09-13 | 2023-09-19 | C.70.10.05.1.20, C.70.10.05.1.13 | as late as possible | HM [240.41 h]; HH [529.28 h] |
| C.70.10.05.1.28 | Preparación de fundación cuerpo de dique | 8d | 2023-09-13 | 2023-09-20 | C.70.10.05.1.22 SS |  | HH [44.93 h]; HM [22.55 h] |
| C.70.10.05.1.23 | Conformación de cuerpo de dique | 1d | 2023-09-20 | 2023-09-20 | C.70.10.05.1.22, C.70.10.05.1.28 FF, C.70.10.05.1.14 | as late as possible | RELLENOS [548.6]; HH [113.12 h]; HM [72.42 h] |
| C.70.10.05.1.21 | Excavación de uña con equipo | 4d | 2023-09-21 | 2023-09-24 | C.70.10.05.1.23, C.70.10.05.1.12 | as late as possible | EXCAVACIONES [2217.6]; HH [137.49 h]; HM [133.06 h] |
| C.70.10.05.1.25 | Instalación de geotextil no tejido | 23d | 2023-09-25 | 2023-10-17 | C.70.10.05.1.21, C.70.10.05.1.16 | as late as possible | HH [264.8 h] |
| C.70.10.05.1.26 | Colocación y acomodo de roca en uña | 10d | 2023-09-25 | 2023-10-04 | C.70.10.05.1.25 SS, C.70.10.05.1.17 | as late as possible | ENROCADOS [2217.6]; HH [979.29 h]; HM [406.49 h] |
| C.70.10.05.1.27 | Colocación y acomodo de roca en talud | 18d | 2023-10-05 | 2023-10-22 | C.70.10.05.1.26, C.70.10.05.1.25 FF, C.70.10.05.1.18 | as late as possible | ENROCADOS [2925.1]; HH [1791.62 h]; HM [658.15 h] |
| C.70.10.05.1.24 | Conformación de corona de dique | 3d | 2023-10-23 | 2023-10-25 | C.70.10.05.1.25, C.70.10.05.1.27, C.70.10.05.1.15 |  | HH [216.74 h]; HM [109.49 h] |

Removed: M.10.01.01.11 Carta de Adjudicación; HITOS CLAVE; M.10.01.01.13 Fecha Clave 1: Acceso al Sitio; M.10.01.01.14 Fecha clave 2: Inicio de excavación; M.10.01.01.15 Fecha Clave 3: Inicio de rellenos; M.10.01.01.16 Fecha Clave 4: Culminación; C.80.02.23 Conformación de desvió en cauce de río Dique A3-I-03 - Sector 1; C.80.02.21 Conformación de desvió en cauce de río Dique A3-I-01; C.70.01.01.18 Desbroce y limpieza Dique A3-I-03 - Sector 1; C.70.01.01.16 Desbroce y limpieza Dique A3-I-01; C.70.01.02.17 Descolmatación Dique A3-I-03 - Sector 1; C.70.01.02.25 Relleno no estructural Dique A3-I-03 - Sector 1; C.70.01.02.15 Descolmatación Dique A3-I-01; C.70.01.02.23 Relleno no estructural Dique A3-I-01

Changed:

| ID | Task | Start | Finish | Duration | Total float | Predecessors | Other |
| --- | --- | --- | --- | --- | --- | --- | --- |
| 000 | **GENERALES** | 2023-04-25 → 2023-05-02 (+7d) |  |  |  |  |  |
| M | **GESTION** | 2023-04-25 → 2023-05-02 (+7d) |  |  |  |  |  |
| 10 | **CONTROL DE PROYECTOS** | 2023-04-25 → 2023-05-02 (+7d) |  |  |  |  |  |
| 01 | **HITOS DE CONTROL** | 2023-04-25 → 2023-05-02 (+7d) |  |  |  |  |  |
| 01 | **HITOS CLAVE** | 2023-04-25 → 2023-05-02 (+7d) |  |  |  |  |  |
| M.10.01.01.11 | KOM |  |  |  |  | Carta de Adjudicación SS+7d → none |  |
| C | **CONSTRUCCION** | 2023-04-25 → 2023-05-02 (+7d) |  |  |  |  |  |
| 90 | **TRABAJOS PRELIMINARES** | 2023-04-25 → 2023-05-02 (+7d) |  |  |  |  |  |
| C.90.02.01.11 | Movilización inicial de equipos - Movimiento de Tierras |  |  |  |  |  | was named Movilización de equipos - Movimiento de Tierras |
| 03 | **GASTOS GENERALES** | 2023-04-25 → 2023-05-02 (+7d) |  |  |  |  |  |
| C.90.03.11 | Gastos Generales | 2023-04-25 → 2023-05-02 (+7d) |  | 222d → 215d |  | Carta de Adjudicación SS → M.10.01.01.11 SS |  |
| M.10.01.02.13 | Hito Planificado 3: Inicio de rellenos |  |  |  | 172d → 42d | C.70.10.01.14 SS → M.10.01.02.12 SS+22d |  |
| 01 | **MOVILIZACIÓN** | 2023-09-22 → 2023-10-12 (+20d) | 2023-10-05 → 2023-10-27 (+22d) |  |  |  |  |
| C.90.02.01.12 | Movilización de equipos - Paisajismo | 2023-09-22 → 2023-10-12 (+20d) | 2023-10-05 → 2023-10-27 (+22d) | 14d → 16d | 26d → 3d | C.70.10.04.15 → C.70.10.04.18 SS | constraint none → as late as possible |
| C.90.02.02.11 | Topografia y georreferenciación |  |  |  |  | Fecha Clave 1: Acceso al Sitio SS → M.10.01.02.11 SS |  |
| C.90.02.02.12 | Trazo y replanteo preliminar - Paisajismo | 2023-10-06 → 2023-10-28 (+22d) | 2023-11-03 → 2023-11-26 (+23d) | 29d → 30d | 26d → 3d |  |  |
| C.90.02.03.11 | Seguridad y salud ocupacional |  |  |  |  | Fecha Clave 1: Acceso al Sitio SS → M.10.01.02.11 SS |  |
| 04 | **INSTALACIONES PROVISIONALES PARA OBRA** |  | 2023-11-25 → 2023-11-15 (-10d) |  |  |  |  |
| C.90.02.04.11 | Instalación de facilidades de obra |  | 2023-06-01 → 2023-06-07 (+6d) | 15d → 21d | 182d → 176d |  |  |
| C.90.02.04.12 | Colocación de Cartel de Identificación | 2023-06-02 → 2023-06-08 (+6d) | 2023-06-03 → 2023-06-09 (+6d) |  | 182d → 176d |  |  |
| C.90.02.04.13 | Gastos de facilidades de obra | 2023-06-04 → 2023-06-10 (+6d) | 2023-11-25 → 2023-11-15 (-10d) | 175d → 159d |  |  |  |
| C.90.02.05.12 | Acondicionamiento de DME |  |  |  |  |  | resources HH [11281.2 h]; HM [7658.81 h] → HH [10194.5 h]; HM [6934.33 h] |
| C.90.02.05.11 | Restauración de áreas de instalaciones provisionales |  |  |  |  |  | resources HH [144 h]; HM [41.6 h] → HH [142.8 h]; HM [40.8 h] |
| C.90.02.06.11 | Implementación del Plan para la vigilancia, prevención y control de COVID -19 |  |  |  |  | M.10.01.02.11 SS, Fecha clave 2: Inicio de excavación SS → M.10.01.02.11 SS |  |
| 07 | **TRANSPORTE** |  | 2023-10-19 → 2023-11-15 (+27d) |  |  |  |  |
| C.90.02.07.15 | Transporte de material excedente < 1km |  | 2023-08-11 → 2023-10-24 (+74d) | 81d → 155d | 59d → 0d |  | resources HH [10211.6 h]; HM [7294 h] → HH [10644.7 h]; HM [7499.14 h] |
| C.90.02.07.16 | Transporte de material excedente >1km |  | 2023-08-11 → 2023-10-24 (+74d) | 81d → 155d | 59d → 0d |  | resources HH [82761.8 h]; HM [59115.6 h] → HH [86271.8 h]; HM [60778.2 h] |
| C.90.02.07.13 | Transporte de roca <1km | 2023-06-22 → 2023-06-28 (+6d) | 2023-10-13 → 2023-11-13 (+31d) | 114d → 139d | 37d → 0d |  | resources HH [3375.69 h]; HM [2411.21 h] → HH [3518.86 h]; HM [2479.03 h] |
| C.90.02.07.14 | Transporte de roca >1km | 2023-06-22 → 2023-06-28 (+6d) | 2023-08-31 → 2023-11-13 (+74d) | 71d → 139d | 37d → 0d |  | resources HH [52038.6 h]; HM [37170.4 h] → HH [54245.6 h]; HM [38215.8 h] |
| C.90.02.07.11 | Transporte de material granular < 1km | 2023-06-28 → 2023-10-21 (+115d) | 2023-10-19 → 2023-11-15 (+27d) | 114d → 26d | 37d → 0d |  | resources HH [799.16 h]; HM [570.83 h] → HH [833.06 h]; HM [586.89 h] |
| C.90.02.07.12 | Transporte de material granular >1km | 2023-06-28 → 2023-10-21 (+115d) | 2023-10-19 → 2023-11-15 (+27d) | 114d → 26d | 37d → 0d |  | resources HH [387.33 h]; HM [276.66 h] → HH [403.75 h]; HM [284.44 h] |
| C.90.02.08.11 | Mantenimiento de tránsito y seguridad vial |  |  |  |  |  | resources HH [18912.9 h]; HM [5834.84 h] → HH [18108.1 h]; HM [4024.02 h] |
| 80 | **FACILIDADES DE OBRA** |  | 2023-06-22 → 2023-07-03 (+11d) |  |  |  |  |
| 02 | **DEMOLICIONES** |  | 2023-06-22 → 2023-07-03 (+11d) |  |  |  |  |
| C.80.02.16 | Demolición de sifon invertido |  |  |  | 156d → 144d | C.70.01.01.12 SS, Desbroce y limpieza Dique A3-I-01 SS → C.70.01.01.12 SS, C.70.01.01.16.1 SS | resources HH [11.38 h]; HM [10.14 h] → HH [11.36 h]; HM [10.13 h] |
| C.80.02.11 | Demolición de estructuras existentes - Punto de agua 1 |  |  |  | 167d → 157d |  | resources HH [3.81 h]; HM [3.4 h] → HH [3.81 h]; HM [3.39 h] |
| C.80.02.12 | Demolición de estructuras existentes - Punto de agua 2 |  |  |  | 167d → 157d |  | resources HH [3.81 h]; HM [3.4 h] → HH [3.81 h]; HM [3.39 h] |
| C.80.02.13 | Demolición de estructuras existentes - Punto de agua 3 |  |  |  | 167d → 157d |  | resources HH [19.07 h]; HM [16.99 h] → HH [19.03 h]; HM [16.96 h] |
| C.80.02.15 | Demolición de canal 3 | 2023-06-18 → 2023-06-23 (+5d) | 2023-06-22 → 2023-06-27 (+5d) |  | 132d → 109d | C.70.01.01.12, Desbroce y limpieza Dique A3-I-01 → C.70.01.01.12, C.70.01.01.16.1 | resources HH [849.44 h]; HM [756.71 h] → HH [847.95 h]; HM [755.71 h] |
| C.80.02.14 | Demolición de canal 1 | 2023-06-08 → 2023-06-26 (+18d) | 2023-06-15 → 2023-07-03 (+18d) |  | 29d → 24d |  | resources HH [1452.92 h]; HM [1294.3 h] → HH [1450.36 h]; HM [1292.6 h] |
| 04 | **OBRAS DE DESVIO TEMPORAL** |  | 2023-06-19 → 2023-06-26 (+7d) |  |  |  |  |
| C.80.02.19 | Conformación de desvió en cauce de río Dique A3-D-02 - Sector 2 |  | 2023-05-24 → 2023-05-30 (+6d) | 3d → 9d | 69d → 19d |  |  |
| C.80.02.17 | Conformación de desvió en cauce de río Dique A3-D-01 |  | 2023-05-26 → 2023-05-29 (+3d) | 2d → 5d | 105d → 42d |  |  |
| C.80.02.20 | Conformación de desvió en cauce de río Dique A3-D-02 - Sector 3 | 2023-06-08 → 2023-06-03 (-5d) | 2023-06-11 → 2023-06-06 (-5d) |  | 2d → 8d | C.70.01.01.15 → C.70.01.01.15 SS+12d |  |
| C.80.02.24 | Conformación de desvió en cauce de río Dique A3-I-03 - Sector 2 | 2023-06-05 → 2023-06-03 (-2d) |  | 4d → 6d | 38d → 0d | C.70.01.01.19 → C.70.01.01.19 SS+12d |  |
| C.80.02.18 | Conformación de desvió en cauce de río Dique A3-D-02 - Sector 1 | 2023-06-01 → 2023-06-12 (+11d) | 2023-06-02 → 2023-06-16 (+14d) | 2d → 5d | 77d → 7d |  |  |
| C.80.02.22 | Conformación de desvió en cauce de río Dique A3-I-02 | 2023-06-08 → 2023-06-25 (+17d) | 2023-06-09 → 2023-06-26 (+17d) |  |  |  |  |
| 70 | **OBRAS EXTERIORES** |  | 2023-11-03 → 2023-11-26 (+23d) |  |  |  |  |
| 01 | **PREPARACION DEL SITIO** |  | 2023-07-04 → 2023-07-19 (+15d) |  |  |  |  |
| 01 | **LIMPIEZA** |  | 2023-06-17 → 2023-06-25 (+8d) |  |  |  |  |
| C.70.01.01.11 | Roce y limpieza de vías |  |  |  | 168d → 158d | Fecha Clave 1: Acceso al Sitio SS → M.10.01.02.11 SS |  |
| C.70.01.01.14 | Desbroce y limpieza Dique A3-D-02 - Sector 2 |  | 2023-06-05 → 2023-06-23 (+18d) | 15d → 33d | 69d → 19d |  | resources HH [4426.92 h]; HM [1351.21 h] → HH [3915.65 h]; HM [1213.24 h] |
| C.70.01.01.15 | Desbroce y limpieza Dique A3-D-02 - Sector 3 |  | 2023-06-07 → 2023-06-25 (+18d) | 17d → 35d | 2d → 8d |  | resources HH [4825.88 h]; HM [1472.98 h] → HH [4268.54 h]; HM [1322.58 h] |
| C.70.01.01.19 | Desbroce y limpieza Dique A3-I-03 - Sector 2 |  | 2023-06-04 → 2023-06-24 (+20d) | 14d → 34d | 38d → 0d |  | resources HH [4157.53 h]; HM [1268.98 h] → HH [3677.38 h]; HM [1139.42 h] |
| C.70.01.01.12 | Desbroce y limpieza Dique A3-D-01 |  | 2023-05-30 → 2023-06-08 (+9d) | 7d → 16d | 105d → 42d |  | resources HH [2106.26 h]; HM [642.88 h] → HH [1863.01 h]; HM [577.24 h] |
| C.70.01.01.13 | Desbroce y limpieza Dique A3-D-02 - Sector 1 |  | 2023-05-31 → 2023-06-11 (+11d) | 8d → 19d | 77d → 7d |  | resources HH [2267.45 h]; HM [692.08 h] → HH [2005.58 h]; HM [621.42 h] |
| C.70.01.01.17 | Desbroce y limpieza Dique A3-I-02 |  | 2023-06-07 → 2023-06-24 (+17d) | 15d → 32d |  |  | resources HH [4400.09 h]; HM [1343.02 h] → HH [3891.92 h]; HM [1205.89 h] |
| 02 | **DESCOLMATACIÓN** |  | 2023-07-04 → 2023-07-19 (+15d) |  |  |  |  |
| C.70.01.02.13 | Descolmatación Dique A3-D-02 - Sector 2 |  | 2023-05-29 → 2023-06-13 (+15d) | 8d → 23d | 69d → 19d |  |  |
| C.70.01.02.21 | Relleno no estructural Dique A3-D-02 - Sector 2 |  | 2023-05-24 → 2023-05-30 (+6d) | 3d → 9d | 69d → 19d |  |  |
| C.70.01.02.11 | Descolmatación Dique A3-D-01 |  | 2023-05-29 → 2023-06-05 (+7d) | 4d → 11d | 105d → 42d |  |  |
| C.70.01.02.19 | Relleno no estructural Dique A3-D-01 |  | 2023-05-28 → 2023-05-31 (+3d) | 2d → 5d | 105d → 42d |  |  |
| C.70.01.02.14 | Descolmatación Dique A3-D-02 - Sector 3 | 2023-06-12 → 2023-06-07 (-5d) | 2023-06-20 → 2023-06-16 (-4d) | 9d → 10d | 2d → 8d |  |  |
| C.70.01.02.18 | Descolmatación Dique A3-I-03 - Sector 2 |  | 2023-06-16 → 2023-06-20 (+4d) | 8d → 12d | 38d → 0d |  |  |
| C.70.01.02.12 | Descolmatación Dique A3-D-02 - Sector 1 | 2023-06-03 → 2023-06-17 (+14d) | 2023-06-06 → 2023-06-29 (+23d) | 4d → 13d | 77d → 7d |  |  |
| C.70.01.02.22 | Relleno no estructural Dique A3-D-02 - Sector 3 | 2023-06-21 → 2023-06-17 (-4d) | 2023-06-24 → 2023-06-20 (-4d) |  | 2d → 8d |  |  |
| C.70.01.02.26 | Relleno no estructural Dique A3-I-03 - Sector 2 | 2023-06-17 → 2023-06-21 (+4d) | 2023-06-20 → 2023-06-26 (+6d) | 4d → 6d | 38d → 0d |  |  |
| C.70.01.02.16 | Descolmatación Dique A3-I-02 | 2023-06-10 → 2023-06-27 (+17d) | 2023-06-17 → 2023-07-04 (+17d) |  |  |  |  |
| C.70.01.02.20 | Relleno no estructural Dique A3-D-02 - Sector 1 | 2023-06-07 → 2023-06-30 (+23d) | 2023-06-08 → 2023-07-04 (+26d) | 2d → 5d | 77d → 7d |  |  |
| C.70.01.02.24 | Relleno no estructural Dique A3-I-02 | 2023-06-18 → 2023-07-05 (+17d) | 2023-06-19 → 2023-07-06 (+17d) |  |  |  |  |

| ID | Task | Start | Finish | Duration | Total float | Predecessors | Other |
| --- | --- | --- | --- | --- | --- | --- | --- |
| C.70.02.01.01.11 | Mejoramiento de vías - Vía Acceso AN-879 |  |  |  |  |  | resources HH [172.72 h]; HM [52.43 h] → HH [168.34 h]; HM [49.51 h] |
| C.70.02.01.01.14 | Mejoramiento de vías - EMPALME CHACHAPOYAS |  |  |  |  |  | resources HH [80.06 h]; HM [24.3 h] → HH [78.03 h]; HM [22.95 h] |
| C.70.02.01.01.13 | Mejoramiento de vías - EMPALME CANAL - DME-3A |  |  |  | 167d → 157d |  | resources HH [222.38 h]; HM [67.51 h] → HH [216.75 h]; HM [63.75 h] |
| C.70.02.01.01.12 | Mejoramiento de vías - FA-07 --AN-879 |  |  |  | 167d → 157d |  | resources HH [208.3 h]; HM [63.23 h] → HH [203.03 h]; HM [59.72 h] |
| 01 | **PUNTO DE AGUA 1** |  | 2023-06-03 → 2023-06-04 (+1d) |  |  |  |  |
| C.70.02.01.02.01.11 | Suministro de paneles de C°A° |  | 2023-06-03 → 2023-06-04 (+1d) | 2d → 3d | 175d → 164d |  | resources HH [5.01 h]; HM [1.34 h] → HH [98.14 h]; HM [35.36 h] |
| C.70.02.01.02.03.11 | Reposición de pase agua tubo HDPE 36" |  |  |  | 167d → 157d |  | resources HH [108.76 h]; HM [38.35 h] → HH [10.55 h]; HM [2.95 h] |
| C.70.02.01.02.03.12 | Reposición de pase agua tubo HDPE 18" |  | 2023-06-05 → 2023-06-06 (+1d) | 0d → 2d | 170d → 158d |  | resources none → HH [4.98 h]; HM [1.32 h] |
| 03 | **PLANTACIÓN Y PAISAJISMO** | 2023-10-06 → 2023-10-28 (+22d) | 2023-10-20 → 2023-11-12 (+23d) |  |  |  |  |
| 01 | **MOVIMIENTO DE TIERRAS** | 2023-10-06 → 2023-10-28 (+22d) | 2023-10-09 → 2023-10-31 (+22d) |  |  |  |  |
| C.70.03.01.11 | Excavación manual para instalación de bordillos | 2023-10-06 → 2023-10-28 (+22d) | 2023-10-08 → 2023-10-30 (+22d) |  | 26d → 3d | C.90.02.01.12 → C.90.02.01.12, C.70.10.04.15 |  |
| C.70.03.01.13 | Eliminación material excedente | 2023-10-06 → 2023-10-28 (+22d) | 2023-10-09 → 2023-10-31 (+22d) |  | 26d → 3d |  | resources HH [3.21 h]; HM [2.71 h] → HH [3.53 h]; HM [3.02 h] |
| C.70.03.01.12 | Excavación para mejoramiento con tierra vegetal | 2023-10-09 → 2023-10-31 (+22d) | 2023-10-09 → 2023-10-31 (+22d) |  | 26d → 3d |  |  |
| 02 | **PAVIMENTOS, RECUBRIMIENTOS Y BORDILLOS** | 2023-10-10 → 2023-11-01 (+22d) | 2023-10-19 → 2023-11-11 (+23d) |  |  |  |  |
| C.70.03.02.11 | Piso de gravilla | 2023-10-10 → 2023-11-01 (+22d) | 2023-10-11 → 2023-11-02 (+22d) |  | 26d → 3d |  | resources HH [44.55 h]; HM [10.43 h] → HH [44.53 h]; HM [10.41 h] |
| C.70.03.02.13 | Bordillos de piedra de lugar | 2023-10-12 → 2023-11-03 (+22d) | 2023-10-16 → 2023-11-07 (+22d) |  | 26d → 3d |  | resources HH [167.16 h]; HM [1.85 h] → HH [167.13 h]; HM [1.82 h] |
| C.70.03.02.12 | Recubrimiento de piedra de lugar | 2023-10-17 → 2023-11-08 (+22d) | 2023-10-19 → 2023-11-11 (+23d) | 3d → 4d | 26d → 3d |  |  |
| 04 | **INSTALACIÓN DE ALCORQUES** | 2023-10-20 → 2023-11-12 (+23d) | 2023-10-20 → 2023-11-12 (+23d) |  |  |  |  |
| C.70.03.03.11 | Instalación de alcorques de piedra | 2023-10-20 → 2023-11-12 (+23d) | 2023-10-20 → 2023-11-12 (+23d) | 1d → 0d | 26d → 3d |  | resources HH [7.5 h] → none |
| 05 | **MOBILIARIO Y EQUIPAMIENTO URBANO** | 2023-10-21 → 2023-11-12 (+22d) | 2023-11-03 → 2023-11-26 (+23d) |  |  |  |  |
| 01 | **MOBILIARIOS, BARANDAS Y ESCALERAS** | 2023-10-21 → 2023-11-12 (+22d) | 2023-11-03 → 2023-11-26 (+23d) |  |  |  |  |
| C.70.05.01.11 | Escalera de concreto sobre enrocado | 2023-10-21 → 2023-11-12 (+22d) | 2023-10-22 → 2023-11-13 (+22d) |  | 26d → 3d |  |  |
| C.70.05.01.12 | Baranda de madera eucalipto con soga | 2023-10-23 → 2023-11-14 (+22d) | 2023-10-24 → 2023-11-16 (+23d) | 2d → 3d | 26d → 3d |  |  |
| C.70.05.01.13 | Tachos de basura | 2023-10-25 → 2023-11-17 (+23d) | 2023-10-26 → 2023-11-18 (+23d) |  | 26d → 3d |  |  |
| C.70.05.01.14 | Bancas de concreto | 2023-10-27 → 2023-11-19 (+23d) | 2023-10-28 → 2023-11-20 (+23d) |  | 26d → 3d |  |  |
| C.70.05.01.15 | Postes de iluminación | 2023-10-29 → 2023-11-21 (+23d) | 2023-10-30 → 2023-11-22 (+23d) |  | 26d → 3d |  |  |
| C.70.05.01.16 | Señalética informativa | 2023-10-31 → 2023-11-23 (+23d) | 2023-11-01 → 2023-11-24 (+23d) |  | 26d → 3d |  |  |
| C.70.05.01.17 | Bolardos de Piedra | 2023-11-02 → 2023-11-25 (+23d) | 2023-11-03 → 2023-11-26 (+23d) |  | 26d → 3d |  |  |
| 10 | **CUERPOS DE TERRAPLEN** |  | 2023-10-19 → 2023-11-15 (+27d) |  |  |  |  |
| 01 | **DIQUE A3-D-01** |  | 2023-08-08 → 2023-10-04 (+57d) |  |  |  |  |
| C.70.10.01.11 | Excavación en terreno natural con equipo |  | 2023-06-05 → 2023-06-04 (-1d) | 9d → 8d | 105d → 42d |  | resources EXCAVACIONES [6167.17]; HH [382.36 h]; HM [246.69 h] → EXCAVACIONES [6167.17]; HH [319.46 h]; HM [205.98 h] |
| C.70.10.01.13 | Perfilado y compatación en zona de corte | 2023-06-06 → 2023-06-05 (-1d) |  | 8d → 9d | 109d → 42d |  | resources HH [649.14 h]; HM [297.71 h] → HH [635.71 h]; HM [288.76 h] |
| C.70.10.01.19 | Preparación de fundación cuerpo de dique | 2023-06-06 → 2023-06-05 (-1d) | 2023-06-17 → 2023-06-20 (+3d) | 12d → 16d | 109d → 42d |  | resources HH [75.35 h]; HM [38.31 h] → HH [72.28 h]; HM [36.27 h] |
| C.70.10.01.14 | Conformación de cuerpo de dique |  | 2023-06-17 → 2023-06-20 (+3d) | 4d → 7d | 109d → 42d | C.70.10.01.13, C.70.10.01.19 FF → C.70.10.01.13, C.70.10.01.19 FF, M.10.01.02.13 SS | resources RELLENOS [1639.2]; HH [552.9 h]; HM [277.19 h] → RELLENOS [1639.2]; HH [338 h]; HM [216.37 h] |
| C.70.10.01.12 | Excavación de uña con equipo | 2023-06-18 → 2023-06-21 (+3d) | 2023-06-21 → 2023-06-27 (+6d) | 4d → 7d | 109d → 42d |  | resources EXCAVACIONES [2325.01]; HH [159.96 h]; HM [154.85 h] → EXCAVACIONES [2325.01]; HH [144.15 h]; HM [139.5 h] |
| C.70.10.01.16 | Instalación de geotextil no tejido | 2023-06-22 → 2023-06-28 (+6d) | 2023-07-27 → 2023-08-02 (+6d) |  | 109d → 42d |  |  |
| C.70.10.01.17 | Colocación y acomodo de roca en uña | 2023-06-22 → 2023-06-28 (+6d) | 2023-07-04 → 2023-07-26 (+22d) | 13d → 29d | 109d → 42d |  | resources ENROCADOS [2325.01]; HH [794.23 h]; HM [193.67 h] → ENROCADOS [2325.01]; HH [1026.73 h]; HM [426.18 h] |
| C.70.10.01.18 | Colocación y acomodo de roca en talud | 2023-07-05 → 2023-07-27 (+22d) | 2023-08-02 → 2023-09-29 (+58d) | 29d → 65d | 109d → 42d | C.70.10.01.17 → C.70.10.01.17, C.70.10.01.16 FF | resources ENROCADOS [3493.37]; HH [1790.35 h]; HM [436.67 h] → ENROCADOS [3493.37]; HH [2139.69 h]; HM [786.01 h] |
| C.70.10.01.15 | Conformación de corona de dique | 2023-08-03 → 2023-09-30 (+58d) | 2023-08-08 → 2023-10-04 (+57d) | 6d → 5d | 109d → 42d |  | resources HH [399.16 h]; HM [198.73 h] → HH [327.28 h]; HM [165.34 h] |
| 02 | **DIQUE A3-D-02** |  | 2023-10-19 → 2023-11-08 (+20d) |  |  |  |  |
| 1 | **SECTOR 1** | 2023-06-09 → 2023-07-05 (+26d) | 2023-09-09 → 2023-11-08 (+60d) |  |  |  |  |
| C.70.10.02.1.11 | Excavación en terreno natural con equipo | 2023-06-09 → 2023-07-05 (+26d) | 2023-06-29 → 2023-08-08 (+40d) | 21d → 35d | 77d → 7d |  | resources EXCAVACIONES [15433.6]; HH [956.88 h]; HM [617.34 h] → EXCAVACIONES [15433.6]; HH [799.46 h]; HM [515.48 h] |
| C.70.10.02.1.13 | Perfilado y compatación en zona de corte | 2023-06-30 → 2023-08-09 (+40d) | 2023-07-06 → 2023-08-23 (+48d) | 7d → 15d | 77d → 7d |  | resources HH [570.01 h]; HM [261.42 h] → HH [558.22 h]; HM [253.56 h] |
| C.70.10.02.1.19 | Preparación de fundación cuerpo de dique | 2023-06-30 → 2023-08-09 (+40d) | 2023-07-10 → 2023-08-29 (+50d) | 11d → 21d | 77d → 7d |  | resources HH [60.28 h]; HM [30.65 h] → HH [57.83 h]; HM [29.02 h] |
| C.70.10.02.1.14 | Conformación de cuerpo de dique | 2023-07-07 → 2023-08-24 (+48d) | 2023-07-10 → 2023-08-29 (+50d) | 4d → 6d | 77d → 7d |  | resources RELLENOS [1487.3]; HH [501.66 h]; HM [251.5 h] → RELLENOS [1487.3]; HH [306.68 h]; HM [196.32 h] |
| C.70.10.02.1.12 | Excavación de uña con equipo | 2023-07-11 → 2023-08-30 (+50d) | 2023-07-15 → 2023-09-08 (+55d) | 5d → 10d | 77d → 7d |  | resources EXCAVACIONES [3144.9]; HH [216.37 h]; HM [209.45 h] → EXCAVACIONES [3144.9]; HH [194.98 h]; HM [188.69 h] |
| C.70.10.02.1.16 | Instalación de geotextil no tejido | 2023-07-16 → 2023-09-09 (+55d) | 2023-08-16 → 2023-10-10 (+55d) |  | 77d → 7d |  |  |
| C.70.10.02.1.17 | Colocación y acomodo de roca en uña | 2023-07-16 → 2023-09-09 (+55d) | 2023-08-02 → 2023-09-28 (+57d) | 18d → 20d | 77d → 7d |  | resources ENROCADOS [3144.9]; HH [1074.3 h]; HM [261.97 h] → ENROCADOS [3144.9]; HH [1388.79 h]; HM [576.46 h] |
| C.70.10.02.1.18 | Colocación y acomodo de roca en talud | 2023-08-03 → 2023-09-29 (+57d) | 2023-09-03 → 2023-11-03 (+61d) | 32d → 36d | 77d → 7d | C.70.10.02.1.17 → C.70.10.02.1.17, C.70.10.02.1.16 FF | resources ENROCADOS [3901.4]; HH [1999.47 h]; HM [487.68 h] → ENROCADOS [3901.4]; HH [2389.61 h]; HM [877.82 h] |
| C.70.10.02.1.15 | Conformación de corona de dique | 2023-09-04 → 2023-11-04 (+61d) | 2023-09-09 → 2023-11-08 (+60d) | 6d → 5d | 77d → 7d |  | resources HH [384.52 h]; HM [191.44 h] → HH [315.28 h]; HM [159.28 h] |
| 2 | **SECTOR 2** |  | 2023-09-17 → 2023-10-17 (+30d) |  |  |  |  |
| C.70.10.02.2.11 | Excavación en terreno natural con equipo |  | 2023-06-07 → 2023-06-12 (+5d) | 16d → 21d | 69d → 19d |  | resources EXCAVACIONES [17674.7]; HH [1095.83 h]; HM [706.99 h] → EXCAVACIONES [17674.7]; HH [915.55 h]; HM [590.34 h] |
| C.70.10.02.2.13 | Perfilado y compatación en zona de corte | 2023-06-08 → 2023-06-13 (+5d) | 2023-06-21 → 2023-07-05 (+14d) | 14d → 23d | 69d → 19d |  | resources HH [1785.91 h]; HM [819.06 h] → HH [1748.96 h]; HM [794.42 h] |
| C.70.10.02.2.19 | Preparación de fundación cuerpo de dique | 2023-06-08 → 2023-06-13 (+5d) | 2023-06-26 → 2023-07-12 (+16d) | 19d → 30d | 69d → 19d |  | resources HH [117.69 h]; HM [59.84 h] → HH [112.9 h]; HM [56.65 h] |
| C.70.10.02.2.14 | Conformación de cuerpo de dique | 2023-06-22 → 2023-07-06 (+14d) | 2023-06-26 → 2023-07-12 (+16d) | 5d → 7d | 69d → 19d |  | resources RELLENOS [3362.3]; HH [1134.1 h]; HM [568.56 h] → RELLENOS [3362.3]; HH [693.31 h]; HM [443.82 h] |
| C.70.10.02.2.12 | Excavación de uña con equipo | 2023-06-27 → 2023-07-13 (+16d) | 2023-07-03 → 2023-07-22 (+19d) | 7d → 10d | 69d → 19d |  | resources EXCAVACIONES [6494.4]; HH [446.81 h]; HM [432.53 h] → EXCAVACIONES [6494.4]; HH [402.65 h]; HM [389.66 h] |
| C.70.10.02.2.16 | Instalación de geotextil no tejido | 2023-07-04 → 2023-07-23 (+19d) | 2023-09-07 → 2023-09-26 (+19d) |  | 69d → 19d |  |  |
| C.70.10.02.2.17 | Colocación y acomodo de roca en uña | 2023-07-04 → 2023-07-23 (+19d) | 2023-07-27 → 2023-08-18 (+22d) | 24d → 27d | 69d → 19d |  | resources ENROCADOS [6494.4]; HH [2218.49 h]; HM [540.98 h] → ENROCADOS [6494.4]; HH [2867.93 h]; HM [1190.42 h] |
| C.70.10.02.2.18 | Colocación y acomodo de roca en talud | 2023-07-28 → 2023-08-19 (+22d) | 2023-09-11 → 2023-10-08 (+27d) | 46d → 51d | 69d → 19d | C.70.10.02.2.17 → C.70.10.02.2.17, C.70.10.02.2.16 FF | resources ENROCADOS [8322.3]; HH [4265.18 h]; HM [1040.29 h] → ENROCADOS [8322.3]; HH [5097.41 h]; HM [1872.52 h] |
| C.70.10.02.2.15 | Conformación de corona de dique | 2023-09-12 → 2023-10-09 (+27d) | 2023-09-17 → 2023-10-17 (+30d) | 6d → 9d | 69d → 19d |  | resources HH [781.74 h]; HM [389.21 h] → HH [640.97 h]; HM [323.82 h] |
| 3 | **SECTOR 3** | 2023-06-25 → 2023-06-21 (-4d) | 2023-10-19 → 2023-11-07 (+19d) |  |  |  |  |
| C.70.10.02.3.10 | Excavación en terreno natural con equipo | 2023-06-25 → 2023-06-21 (-4d) | 2023-07-12 → 2023-07-06 (-6d) | 18d → 16d | 2d → 8d |  | resources EXCAVACIONES [20177.7]; HH [1251.02 h]; HM [807.11 h] → EXCAVACIONES [20177.7]; HH [1045.2 h]; HM [673.93 h] |
| C.70.10.02.3.12 | Perfilado y compatación en zona de corte | 2023-07-13 → 2023-07-07 (-6d) | 2023-07-25 → 2023-07-28 (+3d) | 13d → 22d | 37d → 8d |  | resources HH [1686.27 h]; HM [773.36 h] → HH [1651.38 h]; HM [750.1 h] |
| C.70.10.02.3.18 | Preparación de fundación cuerpo de dique | 2023-07-13 → 2023-07-07 (-6d) | 2023-07-29 → 2023-08-01 (+3d) | 17d → 26d | 37d → 8d |  | resources HH [128.29 h]; HM [65.23 h] → HH [123.07 h]; HM [61.75 h] |
| C.70.10.02.3.13 | Conformación de cuerpo de dique | 2023-07-26 → 2023-07-29 (+3d) | 2023-07-29 → 2023-08-01 (+3d) |  | 37d → 8d |  | resources RELLENOS [2091.3]; HH [705.39 h]; HM [353.64 h] → RELLENOS [2091.3]; HH [431.23 h]; HM [276.05 h] |
| C.70.10.02.3.11 | Excavación de uña con equipo | 2023-07-30 → 2023-08-02 (+3d) | 2023-08-05 → 2023-08-12 (+7d) | 7d → 11d | 37d → 8d |  | resources EXCAVACIONES [7079.69]; HH [487.08 h]; HM [471.51 h] → EXCAVACIONES [7079.69]; HH [438.94 h]; HM [424.78 h] |
| C.70.10.02.3.15 | Instalación de geotextil no tejido | 2023-08-06 → 2023-08-13 (+7d) | 2023-10-06 → 2023-10-13 (+7d) |  | 37d → 8d |  |  |
| C.70.10.02.3.16 | Colocación y acomodo de roca en uña | 2023-08-06 → 2023-08-13 (+7d) | 2023-08-31 → 2023-09-10 (+10d) | 26d → 29d | 37d → 8d |  | resources ENROCADOS [7079.69]; HH [2418.42 h]; HM [589.74 h] → ENROCADOS [7079.69]; HH [3126.39 h]; HM [1297.71 h] |
| C.70.10.02.3.17 | Colocación y acomodo de roca en talud | 2023-09-01 → 2023-09-11 (+10d) | 2023-10-13 → 2023-10-28 (+15d) | 43d → 48d | 37d → 8d | C.70.10.02.3.16, C.90.02.07.13 FF, C.90.02.07.14 → C.70.10.02.3.16, C.70.10.02.3.15 FF | resources ENROCADOS [7799.43]; HH [3997.21 h]; HM [974.93 h] → ENROCADOS [7799.43]; HH [4777.15 h]; HM [1754.87 h] |
| C.70.10.02.3.14 | Conformación de corona de dique | 2023-10-14 → 2023-10-29 (+15d) | 2023-10-19 → 2023-11-07 (+19d) | 6d → 10d | 37d → 8d | C.70.10.02.3.17, C.70.10.02.3.15, C.90.02.07.12 FF, C.90.02.07.11 FF → C.70.10.02.3.17, C.70.10.02.3.15 | resources HH [850.2 h]; HM [423.29 h] → HH [697.11 h]; HM [352.17 h] |

| ID | Task | Start | Finish | Duration | Total float | Predecessors | Other |
| --- | --- | --- | --- | --- | --- | --- | --- |
| 03 | **DIQUE A3-I-01** | 2023-07-05 → 2023-07-20 (+15d) | 2023-09-27 → 2023-11-15 (+49d) |  |  |  |  |
| C.70.10.03.11 | Excavación en terreno natural con equipo | 2023-07-05 → 2023-07-20 (+15d) | 2023-07-22 → 2023-08-12 (+21d) | 18d → 24d | 58d → 21d | Relleno no estructural Dique A3-I-01 → C.70.01.02.23.1 | resources EXCAVACIONES [13764.5]; HH [853.4 h]; HM [550.58 h] → EXCAVACIONES [10520]; HH [544.94 h]; HM [351.37 h] |
| C.70.10.03.13 | Perfilado y compatación en zona de corte | 2023-07-23 → 2023-08-13 (+21d) | 2023-07-29 → 2023-08-22 (+24d) | 7d → 10d | 59d → 35d |  | resources HH [568.42 h]; HM [260.69 h] → HH [374.6 h]; HM [170.15 h] |
| C.70.10.03.19 | Preparación de fundación cuerpo de dique | 2023-07-23 → 2023-08-13 (+21d) | 2023-08-07 → 2023-08-24 (+17d) | 16d → 12d | 59d → 35d |  | resources HH [100.57 h]; HM [51.14 h] → HH [59.17 h]; HM [29.69 h] |
| C.70.10.03.14 | Conformación de cuerpo de dique | 2023-07-30 → 2023-08-23 (+24d) | 2023-08-07 → 2023-08-24 (+17d) | 9d → 2d | 59d → 35d |  | resources RELLENOS [578.56]; HH [1137.26 h]; HM [570.15 h] → RELLENOS [470.6]; HH [97.04 h]; HM [62.12 h] |
| C.70.10.03.12 | Excavación de uña con equipo | 2023-08-08 → 2023-08-25 (+17d) | 2023-08-11 → 2023-08-29 (+18d) | 4d → 5d | 59d → 35d | C.70.10.03.14, C.90.02.07.16 FF, C.90.02.07.15 FF → C.70.10.03.14 | resources EXCAVACIONES [2275.54]; HH [156.56 h]; HM [151.55 h] → EXCAVACIONES [1395.54]; HH [86.52 h]; HM [83.73 h] |
| C.70.10.03.16 | Instalación de geotextil no tejido | 2023-08-12 → 2023-08-30 (+18d) | 2023-09-15 → 2023-09-18 (+3d) | 35d → 20d | 59d → 35d |  | resources HH [408.93 h] → HH [231.77 h] |
| C.70.10.03.17 | Colocación y acomodo de roca en uña | 2023-08-12 → 2023-08-30 (+18d) | 2023-08-24 → 2023-09-07 (+14d) | 13d → 9d | 59d → 35d |  | resources ENROCADOS [2275.54]; HH [777.33 h]; HM [189.55 h] → ENROCADOS [1395.54]; HH [616.27 h]; HM [255.8 h] |
| C.70.10.03.18 | Colocación y acomodo de roca en talud | 2023-08-25 → 2023-09-08 (+14d) | 2023-09-21 → 2023-09-25 (+4d) | 28d → 18d | 59d → 35d | C.70.10.03.17 → C.70.10.03.17, C.70.10.03.16 FF | resources ENROCADOS [3426.26]; HH [1755.96 h]; HM [428.28 h] → ENROCADOS [1900.76]; HH [1164.22 h]; HM [427.67 h] |
| C.70.10.03.15 | Conformación de corona de dique | 2023-09-22 → 2023-09-26 (+4d) | 2023-09-27 → 2023-09-28 (+1d) | 6d → 3d | 59d → 46d |  | resources HH [391.04 h]; HM [194.69 h] → HH [196.64 h]; HM [99.34 h] |
| 04 | **DIQUE A3-I-02** | 2023-06-20 → 2023-07-07 (+17d) | 2023-09-21 → 2023-10-27 (+36d) |  |  |  |  |
| C.70.10.04.11 | Excavación en terreno natural con equipo | 2023-06-20 → 2023-07-07 (+17d) | 2023-07-14 → 2023-07-27 (+13d) | 25d → 21d |  |  | resources EXCAVACIONES [18781.3]; HH [1164.44 h]; HM [751.25 h] → EXCAVACIONES [18781.3]; HH [972.87 h]; HM [627.3 h] |
| C.70.10.04.13 | Perfilado y compatación en zona de corte | 2023-07-15 → 2023-07-28 (+13d) | 2023-07-22 → 2023-08-14 (+23d) | 8d → 18d | 26d → 3d |  | resources HH [707.84 h]; HM [324.63 h] → HH [693.19 h]; HM [314.87 h] |
| C.70.10.04.19 | Preparación de fundación cuerpo de dique | 2023-07-15 → 2023-07-28 (+13d) | 2023-07-22 → 2023-08-17 (+26d) | 8d → 21d | 26d → 3d |  | resources HH [41.76 h]; HM [21.23 h] → HH [40.06 h]; HM [20.1 h] |
| C.70.10.04.14 | Conformación de cuerpo de dique | 2023-07-23 → 2023-08-15 (+23d) | 2023-07-23 → 2023-08-17 (+25d) | 0d → 3d | 26d → 3d |  | resources none → HH [119.3 h]; HM [76.37 h] |
| C.70.10.04.12 | Excavación de uña con equipo | 2023-07-23 → 2023-08-18 (+26d) | 2023-07-27 → 2023-08-27 (+31d) | 5d → 10d | 26d → 3d |  | resources EXCAVACIONES [3101.07]; HH [213.35 h]; HM [206.53 h] → EXCAVACIONES [3101.07]; HH [192.27 h]; HM [186.06 h] |
| C.70.10.04.16 | Instalación de geotextil no tejido | 2023-07-28 → 2023-08-28 (+31d) | 2023-08-27 → 2023-09-27 (+31d) |  | 26d → 3d |  |  |
| C.70.10.04.17 | Colocación y acomodo de roca en uña | 2023-07-28 → 2023-08-28 (+31d) | 2023-08-13 → 2023-09-15 (+33d) | 17d → 19d | 26d → 3d |  | resources ENROCADOS [3101.07]; HH [1059.32 h]; HM [258.32 h] → ENROCADOS [3101.07]; HH [1369.43 h]; HM [568.43 h] |
| C.70.10.04.18 | Colocación y acomodo de roca en talud | 2023-08-14 → 2023-09-16 (+33d) | 2023-09-14 → 2023-10-21 (+37d) | 32d → 36d | 26d → 3d | C.70.10.04.17 → C.70.10.04.17, C.70.10.04.16 FF | resources ENROCADOS [3837.2]; HH [1966.57 h]; HM [479.65 h] → ENROCADOS [3837.2]; HH [2350.29 h]; HM [863.37 h] |
| C.70.10.04.15 | Conformación de corona de dique | 2023-09-15 → 2023-10-22 (+37d) | 2023-09-21 → 2023-10-27 (+36d) | 7d → 6d | 26d → 3d |  | resources HH [463.56 h]; HM [230.79 h] → HH [380.09 h]; HM [192.02 h] |
| 05 | **DIQUE A3-I-03** | 2023-06-17 → 2023-06-27 (+10d) | 2023-10-18 → 2023-11-15 (+28d) |  |  |  |  |
| 1 | **SECTOR 1** | 2023-06-17 → 2023-07-13 (+26d) | 2023-10-08 → 2023-10-25 (+17d) |  |  |  |  |
| C.70.10.05.1.11 | Excavación en terreno natural con equipo | 2023-06-17 → 2023-07-13 (+26d) | 2023-07-02 → 2023-07-22 (+20d) | 16d → 10d | 48d → 2d | Relleno no estructural Dique A3-I-03 - Sector 1 → C.70.01.02.25.1 | resources EXCAVACIONES [17723]; HH [1098.83 h]; HM [708.92 h] → EXCAVACIONES [12197.4]; HH [631.83 h]; HM [407.39 h] |
| C.70.10.05.1.13 | Perfilado y compatación en zona de corte | 2023-07-03 → 2023-07-23 (+20d) | 2023-07-14 → 2023-08-03 (+20d) |  | 48d → 2d |  | resources HH [1555.17 h]; HM [713.23 h] → HH [993.72 h]; HM [451.37 h] |
| C.70.10.05.1.19 | Preparación de fundación cuerpo de dique | 2023-07-03 → 2023-07-23 (+20d) | 2023-07-16 → 2023-08-05 (+20d) |  | 48d → 2d |  | resources HH [137.16 h]; HM [69.74 h] → HH [86.65 h]; HM [43.48 h] |
| C.70.10.05.1.14 | Conformación de cuerpo de dique | 2023-07-15 → 2023-08-04 (+20d) | 2023-07-16 → 2023-08-05 (+20d) |  | 48d → 2d |  | resources RELLENOS [1359.4]; HH [458.53 h]; HM [229.87 h] → RELLENOS [810.8]; HH [167.19 h]; HM [107.03 h] |
| C.70.10.05.1.12 | Excavación de uña con equipo | 2023-07-17 → 2023-08-06 (+20d) | 2023-07-23 → 2023-08-11 (+19d) | 7d → 6d | 48d → 2d |  | resources EXCAVACIONES [6494.4]; HH [446.81 h]; HM [432.53 h] → EXCAVACIONES [4276.8]; HH [265.16 h]; HM [256.61 h] |
| C.70.10.05.1.16 | Instalación de geotextil no tejido | 2023-07-24 → 2023-08-12 (+19d) | 2023-09-27 → 2023-09-24 (-3d) | 66d → 44d | 48d → 2d |  | resources ENROCADOS [10055.1]; HH [779.27 h] → HH [514.48 h] |
| C.70.10.05.1.17 | Colocación y acomodo de roca en uña | 2023-07-24 → 2023-08-12 (+19d) | 2023-08-16 → 2023-08-29 (+13d) | 24d → 18d | 48d → 3d |  | resources ENROCADOS [6494.4]; HH [2218.49 h]; HM [540.98 h] → ENROCADOS [4276.8]; HH [1888.63 h]; HM [783.94 h] |
| C.70.10.05.1.18 | Colocación y acomodo de roca en talud | 2023-08-17 → 2023-08-30 (+13d) | 2023-10-02 → 2023-10-03 (+1d) | 47d → 35d | 48d → 3d | C.70.10.05.1.17 → C.70.10.05.1.17, C.70.10.05.1.16 FF | resources HH [4418.21 h]; HM [1077.61 h] → HH [3488.68 h]; HM [1281.56 h]; ENROCADOS [5695.8] |
| C.70.10.05.1.15 | Conformación de corona de dique | 2023-10-03 → 2023-10-04 (+1d) | 2023-10-08 → 2023-10-09 (+1d) |  | 48d → 32d | C.70.10.05.1.18 → C.70.10.05.1.18, C.70.10.05.1.16 | resources HH [774.8 h]; HM [385.75 h] → HH [418.55 h]; HM [211.45 h] |
| 2 | **SECTOR 2** | 2023-06-21 → 2023-06-27 (+6d) | 2023-10-18 → 2023-11-15 (+28d) |  |  |  |  |
| C.70.10.05.2.11 | Excavación en terreno natural con equipo | 2023-06-21 → 2023-06-27 (+6d) | 2023-07-05 → 2023-07-09 (+4d) | 15d → 13d | 38d → 0d |  | resources EXCAVACIONES [16797.4]; HH [1041.44 h]; HM [671.9 h] → EXCAVACIONES [16797.4]; HH [870.11 h]; HM [561.03 h] |
| C.70.10.05.2.13 | Perfilado y compatación en zona de corte | 2023-07-06 → 2023-07-10 (+4d) | 2023-07-18 → 2023-07-30 (+12d) | 13d → 21d | 38d → 0d |  | resources HH [1716.07 h]; HM [787.02 h] → HH [1680.56 h]; HM [763.35 h] |
| C.70.10.05.2.19 | Preparación de fundación cuerpo de dique | 2023-07-06 → 2023-07-10 (+4d) | 2023-07-25 → 2023-08-07 (+13d) | 20d → 29d | 38d → 0d |  | resources HH [153.89 h]; HM [78.25 h] → HH [147.63 h]; HM [74.08 h] |
| C.70.10.05.2.14 | Conformación de cuerpo de dique | 2023-07-19 → 2023-07-31 (+12d) | 2023-07-25 → 2023-08-07 (+13d) | 7d → 8d | 38d → 0d |  | resources RELLENOS [4286.7]; HH [1445.9 h]; HM [724.88 h] → RELLENOS [4286.7]; HH [883.92 h]; HM [565.84 h] |
| C.70.10.05.2.12 | Excavación de uña con equipo | 2023-07-26 → 2023-08-08 (+13d) | 2023-08-02 → 2023-08-17 (+15d) | 8d → 10d | 38d → 0d |  | resources EXCAVACIONES [7286.4]; HH [501.3 h]; HM [485.27 h] → EXCAVACIONES [7286.4]; HH [451.76 h]; HM [437.18 h] |
| C.70.10.05.2.16 | Instalación de geotextil no tejido | 2023-08-03 → 2023-08-18 (+15d) | 2023-10-05 → 2023-10-20 (+15d) |  | 38d → 0d |  |  |
| C.70.10.05.2.17 | Colocación y acomodo de roca en uña | 2023-08-03 → 2023-08-18 (+15d) | 2023-08-29 → 2023-09-16 (+18d) | 27d → 30d | 38d → 0d |  | resources ENROCADOS [7286.4]; HH [2489.03 h]; HM [606.96 h] → ENROCADOS [7286.4]; HH [3217.67 h]; HM [1335.6 h] |
| C.70.10.05.2.18 | Colocación y acomodo de roca en talud | 2023-08-30 → 2023-09-17 (+18d) | 2023-10-12 → 2023-11-05 (+24d) | 44d → 50d | 38d → 0d | C.70.10.05.2.17 → C.70.10.05.2.17, C.70.10.05.2.16 FF | resources HH [4111.84 h]; HM [1002.89 h] → HH [4914.15 h]; HM [1805.2 h] |
| C.70.10.05.2.15 | Conformación de corona de dique | 2023-10-13 → 2023-11-06 (+24d) | 2023-10-18 → 2023-11-15 (+28d) | 6d → 10d | 38d → 0d | C.70.10.05.2.18 → C.70.10.05.2.18, C.70.10.05.2.16 | resources HH [868.08 h]; HM [432.19 h] → HH [711.77 h]; HM [359.58 h] |
| 11 | **SUPERFICIES DE TERRAPLEN** | 2023-06-27 → 2023-10-18 (+113d) | 2023-07-28 → 2023-10-27 (+91d) |  |  |  |  |
| 01 | **RAMPA A3-RA-D-01** | 2023-06-27 → 2023-10-18 (+113d) | 2023-06-29 → 2023-10-22 (+115d) |  |  |  |  |
| C.70.11.01.11 | Excavación en terreno natural con equipo | 2023-06-27 → 2023-10-18 (+113d) | 2023-06-27 → 2023-10-18 (+113d) |  | 149d → 19d | C.70.10.02.2.14 → C.70.10.02.2.15 | resources HH [15.39 h]; HM [9.93 h] → HH [12.86 h]; HM [8.29 h] |
| C.70.11.01.12 | Conformación de cuerpo de dique | 2023-06-28 → 2023-10-19 (+113d) | 2023-06-28 → 2023-10-20 (+114d) | 0d → 2d | 149d → 19d |  | resources none → HH [17.65 h]; HM [9.81 h] |
| C.70.11.01.13 | Conformación de coronación de rampas | 2023-06-28 → 2023-10-21 (+115d) | 2023-06-29 → 2023-10-22 (+115d) |  | 149d → 19d |  | resources HH [51.11 h]; HM [26.64 h] → HH [26.58 h]; HM [13.43 h] |
| 02 | **RAMPA A3-RA-I-01** | 2023-07-26 → 2023-10-23 (+89d) | 2023-07-28 → 2023-10-27 (+91d) |  |  |  |  |
| C.70.11.02.11 | Excavación en terreno natural con equipo | 2023-07-26 → 2023-10-23 (+89d) | 2023-07-26 → 2023-10-23 (+89d) |  | 120d → 19d | C.70.10.05.2.14 → C.70.10.05.2.14, C.70.11.01.13 | resources HH [11.1 h]; HM [7.16 h] → HH [9.27 h]; HM [5.98 h] |
| C.70.11.02.12 | Conformación de cuerpo de dique | 2023-07-27 → 2023-10-24 (+89d) | 2023-07-27 → 2023-10-25 (+90d) | 0d → 2d | 120d → 19d |  | resources none → HH [16.19 h]; HM [9 h] |
| C.70.11.02.13 | Conformación de coronación de rampas | 2023-07-27 → 2023-10-26 (+91d) | 2023-07-28 → 2023-10-27 (+91d) |  | 120d → 19d |  | resources HH [45.02 h]; HM [23.51 h] → HH [22.85 h]; HM [11.55 h] |
| 60 | **TRABAJOS DE RENOVACIÓN** | 2023-07-05 → 2023-07-28 (+23d) | 2023-11-25 → 2023-11-15 (-10d) |  |  |  |  |
| 02 | **REPARACION DE SERVICIOS EXISTENTES** | 2023-07-05 → 2023-07-28 (+23d) | 2023-11-25 → 2023-11-15 (-10d) |  |  |  |  |
| 01 | **REPOSICION CANAL 1** | 2023-07-15 → 2023-07-28 (+13d) | 2023-11-25 → 2023-11-08 (-17d) |  |  |  |  |
| 01 | **MOVIMIENTO DE TIERRAS** | 2023-07-15 → 2023-07-28 (+13d) | 2023-11-25 → 2023-11-08 (-17d) |  |  |  |  |
| C.60.02.01.01.11 | Excavación en terreno natural con equipo | 2023-07-15 → 2023-07-28 (+13d) | 2023-07-24 → 2023-08-04 (+11d) | 10d → 8d |  |  | resources HH [213.93 h]; HM [138.02 h] → HH [178.74 h]; HM [115.25 h] |
| C.60.02.01.01.12 | Relleno estructural para obras de arte con material propio | 2023-10-06 → 2023-10-14 (+8d) | 2023-11-25 → 2023-11-08 (-17d) | 51d → 26d | 0d → 7d |  | resources HH [1475.72 h]; HM [654.5 h] → HH [1461.07 h]; HM [644.73 h] |
| 02 | **OBRAS DE CONCRETO** | 2023-07-25 → 2023-08-05 (+11d) | 2023-10-06 → 2023-10-14 (+8d) |  |  |  |  |
| C.60.02.01.02.13 | Concreto - solado | 2023-07-25 → 2023-08-05 (+11d) | 2023-07-30 → 2023-08-10 (+11d) |  |  |  |  |
| C.60.02.01.02.12 | Acero de refuerzo | 2023-07-31 → 2023-08-11 (+11d) | 2023-08-19 → 2023-08-27 (+8d) | 20d → 17d |  |  |  |
| C.60.02.01.02.15 | Junta Water Stop | 2023-07-31 → 2023-08-11 (+11d) | 2023-09-05 → 2023-09-13 (+8d) | 37d → 34d |  |  |  |
| C.60.02.01.02.11 | Encofrado recto | 2023-08-20 → 2023-08-28 (+8d) | 2023-09-05 → 2023-09-13 (+8d) |  |  |  |  |
| C.60.02.01.02.14 | Concreto canal | 2023-09-06 → 2023-09-14 (+8d) | 2023-09-18 → 2023-09-26 (+8d) |  |  |  |  |
| C.60.02.01.02.17 | Desencofrado | 2023-09-19 → 2023-09-27 (+8d) | 2023-10-05 → 2023-10-13 (+8d) |  |  |  |  |
| C.60.02.01.02.16 | Mamposteria de piedra | 2023-10-06 → 2023-10-14 (+8d) | 2023-10-06 → 2023-10-14 (+8d) |  | 50d → 0d |  |  |
| 02 | **REPOSICION CANAL 3** | 2023-07-23 → 2023-10-15 (+84d) | 2023-08-15 → 2023-11-15 (+92d) |  |  |  |  |
| 01 | **MOVMIENTO DE TIERRAS** | 2023-07-23 → 2023-10-15 (+84d) | 2023-08-15 → 2023-11-15 (+92d) |  |  |  |  |
| C.60.02.02.01.11 | Excavación en terreno natural con equipo | 2023-07-23 → 2023-10-15 (+84d) | 2023-07-23 → 2023-10-15 (+84d) |  | 102d → 0d | C.80.02.15, C.70.10.01.11, C.70.10.03.11 → C.80.02.15, C.70.10.01.11, C.70.10.03.11, C.60.02.01.02.16 | resources HH [17.2 h]; HM [11.1 h] → HH [14.37 h]; HM [9.27 h] |
| C.60.02.02.01.12 | Relleno estructural para obras de arte con material propio | 2023-08-14 → 2023-11-14 (+92d) | 2023-08-15 → 2023-11-15 (+92d) |  | 102d → 0d |  | resources HH [25.75 h]; HM [11.42 h] → HH [10.79 h]; HM [4.76 h] |
| 02 | **OBRAS DE CONCRETO** | 2023-07-24 → 2023-10-16 (+84d) | 2023-08-14 → 2023-11-14 (+92d) |  |  |  |  |
| C.60.02.02.02.13 | Concreto - solado | 2023-07-24 → 2023-10-16 (+84d) | 2023-07-25 → 2023-10-17 (+84d) |  | 102d → 0d |  |  |

| ID | Task | Start | Finish | Duration | Total float | Predecessors | Other |
| --- | --- | --- | --- | --- | --- | --- | --- |
| C.60.02.02.02.12 | Malla Electrosoldada | 2023-07-26 → 2023-10-18 (+84d) | 2023-08-03 → 2023-10-26 (+84d) |  | 102d → 0d |  |  |
| C.60.02.02.02.15 | Junta Water Stop | 2023-07-26 → 2023-10-18 (+84d) | 2023-08-07 → 2023-11-03 (+88d) | 13d → 17d | 102d → 0d |  |  |
| C.60.02.02.02.11 | Encofrado recto | 2023-08-04 → 2023-10-27 (+84d) | 2023-08-07 → 2023-11-03 (+88d) | 4d → 8d | 102d → 0d |  |  |
| C.60.02.02.02.14 | Concreto canal | 2023-08-08 → 2023-11-04 (+88d) | 2023-08-09 → 2023-11-05 (+88d) |  | 102d → 0d |  |  |
| C.60.02.02.02.17 | Desencofrado | 2023-08-10 → 2023-11-06 (+88d) | 2023-08-13 → 2023-11-13 (+92d) | 4d → 8d | 102d → 0d |  |  |
| C.60.02.02.02.16 | Mamposteria de piedra | 2023-08-14 → 2023-11-14 (+92d) | 2023-08-14 → 2023-11-14 (+92d) |  | 103d → 1d |  |  |
| 03 | **REPOSICION SIFON INOPERATIVO** | 2023-07-05 → 2023-10-16 (+103d) | 2023-08-03 → 2023-11-15 (+104d) |  |  |  |  |
| C.60.02.03.11 | Excavación estructural para obras de arte | 2023-07-05 → 2023-10-16 (+103d) | 2023-07-18 → 2023-10-29 (+103d) |  | 115d → 0d | C.80.02.16, C.70.10.01.11 SS, C.70.10.03.11 SS → C.80.02.16, C.70.10.01.11 SS, C.70.10.03.11 SS, C.60.02.02.01.11 |  |
| C.60.02.03.12 | Colocación de cama de arena | 2023-07-19 → 2023-10-30 (+103d) | 2023-07-19 → 2023-10-30 (+103d) |  | 115d → 0d |  | resources HH [16.07 h]; HM [6.75 h] → HH [15.97 h]; HM [6.69 h] |
| C.60.02.03.15 | Tuberias HDPE | 2023-07-20 → 2023-10-31 (+103d) | 2023-07-21 → 2023-11-01 (+103d) |  | 115d → 0d |  |  |
| C.60.02.03.21 | Codos HDPE | 2023-07-22 → 2023-11-02 (+103d) | 2023-07-23 → 2023-11-03 (+103d) |  | 115d → 0d |  |  |
| C.60.02.03.14 | Relleno comun | 2023-07-24 → 2023-11-04 (+103d) | 2023-07-28 → 2023-11-08 (+103d) |  | 115d → 0d |  | resources HH [86.53 h]; HM [50.82 h] → HH [84.13 h]; HM [49.22 h] |
| C.60.02.03.16 | Concreto - Solado | 2023-07-29 → 2023-11-09 (+103d) | 2023-07-29 → 2023-11-09 (+103d) |  | 115d → 0d |  |  |
| C.60.02.03.20 | Acero de refuerzo | 2023-07-30 → 2023-11-10 (+103d) | 2023-07-30 → 2023-11-10 (+103d) |  | 115d → 0d |  |  |
| C.60.02.03.18 | Encofrado | 2023-07-31 → 2023-11-11 (+103d) | 2023-07-31 → 2023-11-11 (+103d) |  | 115d → 0d |  |  |
| C.60.02.03.17 | Concreto | 2023-08-01 → 2023-11-12 (+103d) | 2023-08-01 → 2023-11-12 (+103d) |  | 115d → 0d |  |  |
| C.60.02.03.19 | Desencofrado | 2023-08-02 → 2023-11-13 (+103d) | 2023-08-02 → 2023-11-13 (+103d) |  | 115d → 0d |  |  |
| C.60.02.03.13 | Rellno estructural para obras de arte con material propio | 2023-08-03 → 2023-11-14 (+103d) | 2023-08-03 → 2023-11-15 (+104d) | 0d → 2d | 115d → 0d |  | resources none → HH [14.7 h]; HM [6.49 h] |
| 21 | **REGISTROS Y CAMARAS** | 2023-07-06 → 2023-07-10 (+4d) | 2023-09-28 → 2023-11-14 (+47d) |  |  |  |  |
| 01 | **CAPTACION A3-CP-23-95** | 2023-07-06 → 2023-07-10 (+4d) | 2023-09-14 → 2023-11-14 (+61d) |  |  |  |  |
| 01 | **MOVIMIENTO DE TIERRAS** | 2023-07-24 → 2023-07-28 (+4d) | 2023-09-12 → 2023-11-03 (+52d) |  |  |  |  |
| C.21.01.01.11 | Excavación estructural para obras de arte | 2023-07-24 → 2023-07-28 (+4d) | 2023-07-31 → 2023-08-04 (+4d) |  | 90d → 1d |  |  |
| C.21.01.01.12 | Relleno estructural para obras de arte con material propio | 2023-09-10 → 2023-11-01 (+52d) | 2023-09-12 → 2023-11-03 (+52d) |  | 74d → 12d |  |  |
| 02 | **OBRAS DE CONCRETO** | 2023-08-01 → 2023-08-05 (+4d) | 2023-08-27 → 2023-08-31 (+4d) |  |  |  |  |
| C.21.01.02.11 | Concreto - solado | 2023-08-01 → 2023-08-05 (+4d) | 2023-08-01 → 2023-08-05 (+4d) |  | 90d → 1d |  |  |
| C.21.01.02.16 | Acero de refuerzo | 2023-08-02 → 2023-08-06 (+4d) | 2023-08-10 → 2023-08-14 (+4d) |  | 90d → 1d |  |  |
| C.21.01.02.14 | Encofrado | 2023-08-11 → 2023-08-15 (+4d) | 2023-08-15 → 2023-08-19 (+4d) |  | 90d → 1d |  |  |
| C.21.01.02.12 | Concreto - muro | 2023-08-16 → 2023-08-20 (+4d) | 2023-08-21 → 2023-08-25 (+4d) |  | 90d → 1d |  |  |
| C.21.01.02.13 | Concreto Ciclopeo | 2023-08-22 → 2023-08-26 (+4d) | 2023-08-22 → 2023-08-26 (+4d) |  | 90d → 1d |  |  |
| C.21.01.02.15 | Desencofrado | 2023-08-23 → 2023-08-27 (+4d) | 2023-08-27 → 2023-08-31 (+4d) |  | 90d → 1d |  |  |
| 03 | **ESTRUCTURAS METALICAS** | 2023-08-02 → 2023-11-02 (+92d) | 2023-08-10 → 2023-11-14 (+96d) |  |  |  |  |
| C.21.01.03.11 | Compuerta metalica | 2023-08-02 → 2023-11-02 (+92d) | 2023-08-02 → 2023-11-05 (+95d) | 0d → 4d | 107d → 1d |  | resources none → HH [51.5 h]; HM [25 h] |
| C.21.01.03.12 | Rejilla | 2023-08-02 → 2023-11-06 (+96d) | 2023-08-02 → 2023-11-06 (+96d) |  | 107d → 1d |  |  |
| C.21.01.03.13 | Baranda de fierro galvanizado | 2023-08-03 → 2023-11-07 (+96d) | 2023-08-03 → 2023-11-07 (+96d) |  | 107d → 1d |  |  |
| C.21.01.03.14 | Escalera tipo gato | 2023-08-04 → 2023-11-08 (+96d) | 2023-08-04 → 2023-11-08 (+96d) |  | 107d → 1d |  |  |
| C.21.01.03.15 | Tapa metálica | 2023-08-05 → 2023-11-09 (+96d) | 2023-08-10 → 2023-11-14 (+96d) |  | 107d → 1d |  |  |
| 04 | **TUBERIA** | 2023-07-06 → 2023-07-10 (+4d) | 2023-08-09 → 2023-08-13 (+4d) |  |  |  |  |
| C.21.01.04.12 | Excavación de zanja | 2023-07-06 → 2023-07-10 (+4d) | 2023-07-13 → 2023-07-17 (+4d) |  | 74d → 1d |  |  |
| C.21.01.04.14 | Cama de arena | 2023-07-14 → 2023-07-18 (+4d) | 2023-07-15 → 2023-07-19 (+4d) |  | 74d → 1d |  | resources HH [30.28 h]; HM [12.73 h] → HH [30.1 h]; HM [12.61 h] |
| C.21.01.04.23 | Instalación tubería | 2023-07-16 → 2023-07-20 (+4d) | 2023-07-17 → 2023-07-21 (+4d) |  | 74d → 1d |  |  |
| C.21.01.04.15 | Relleno común para zanjas | 2023-07-18 → 2023-07-22 (+4d) | 2023-07-23 → 2023-07-27 (+4d) |  | 74d → 1d |  | resources HH [238.05 h]; HM [139.81 h] → HH [231.44 h]; HM [135.41 h] |
| C.21.01.04.11 | Excavación estructural para obras de arte | 2023-07-24 → 2023-07-28 (+4d) | 2023-07-26 → 2023-07-30 (+4d) |  | 74d → 1d |  |  |
| C.21.01.04.16 | Concreto solado - Buzones | 2023-07-27 → 2023-07-31 (+4d) | 2023-07-27 → 2023-07-31 (+4d) |  | 108d → 94d |  |  |
| C.21.01.04.20 | Acero de refuerzo | 2023-07-28 → 2023-08-01 (+4d) | 2023-07-30 → 2023-08-03 (+4d) |  | 108d → 94d |  |  |
| C.21.01.04.18 | Encofrado recto | 2023-07-31 → 2023-08-04 (+4d) | 2023-07-31 → 2023-08-04 (+4d) |  | 110d → 96d |  |  |
| C.21.01.04.19 | Encofrado curvo | 2023-07-31 → 2023-08-04 (+4d) | 2023-08-02 → 2023-08-06 (+4d) |  | 108d → 94d |  |  |
| C.21.01.04.17 | Concreto - Buzones | 2023-08-03 → 2023-08-07 (+4d) | 2023-08-03 → 2023-08-07 (+4d) |  | 108d → 94d |  |  |
| C.21.01.04.21 | Desencofrado recto | 2023-08-04 → 2023-08-08 (+4d) | 2023-08-04 → 2023-08-08 (+4d) |  | 110d → 96d |  |  |
| C.21.01.04.22 | Desencodrado curvo | 2023-08-04 → 2023-08-08 (+4d) | 2023-08-06 → 2023-08-10 (+4d) |  | 108d → 94d |  |  |
| C.21.01.04.13 | Relleno estructural para obras de arte con material propio | 2023-08-07 → 2023-08-11 (+4d) | 2023-08-09 → 2023-08-13 (+4d) |  | 108d → 94d |  | resources HH [51.74 h]; HM [22.95 h] → HH [36.6 h]; HM [16.15 h] |
| 05 | **CANALES** | 2023-07-24 → 2023-09-01 (+39d) | 2023-09-14 → 2023-10-23 (+39d) |  |  |  |  |
| C.21.01.05.11 | Excavación estructural para obras de arte | 2023-07-24 → 2023-09-01 (+39d) | 2023-07-27 → 2023-09-04 (+39d) |  | 74d → 1d | C.21.01.04.11 SS → C.21.01.04.11 SS, C.21.01.02.15 |  |
| C.21.01.05.13 | Colocación solado | 2023-07-28 → 2023-09-05 (+39d) | 2023-07-29 → 2023-09-06 (+39d) |  | 74d → 1d |  |  |
| C.21.01.05.16 | Acero de refuerzo | 2023-07-30 → 2023-09-07 (+39d) | 2023-08-08 → 2023-09-16 (+39d) |  | 74d → 1d |  |  |
| C.21.01.05.18 | Junta Water Stop | 2023-07-30 → 2023-09-07 (+39d) | 2023-08-20 → 2023-09-28 (+39d) |  | 74d → 1d |  |  |
| C.21.01.05.15 | Encofrado | 2023-08-09 → 2023-09-17 (+39d) | 2023-08-20 → 2023-09-28 (+39d) |  | 74d → 1d |  |  |
| C.21.01.05.14 | Colocación concreto | 2023-08-21 → 2023-09-29 (+39d) | 2023-08-28 → 2023-10-06 (+39d) |  | 74d → 1d |  |  |
| C.21.01.05.17 | Desencofrado | 2023-08-29 → 2023-10-07 (+39d) | 2023-09-09 → 2023-10-18 (+39d) |  | 74d → 1d |  |  |
| C.21.01.05.12 | Relleno estructural para canales | 2023-09-10 → 2023-10-19 (+39d) | 2023-09-14 → 2023-10-23 (+39d) |  | 74d → 1d |  | resources HH [413.99 h]; HM [183.61 h] → HH [409.88 h]; HM [180.87 h] |
| 06 | **OBRAS DE DESCARGA** | 2023-07-24 → 2023-10-24 (+92d) | 2023-08-06 → 2023-11-03 (+89d) |  |  |  |  |
| C.21.01.06.11 | Excavación estructural para obras de arte | 2023-07-24 → 2023-10-24 (+92d) | 2023-07-24 → 2023-10-24 (+92d) |  | 107d → 1d | C.21.01.04.11 SS → C.21.01.04.11 SS, C.21.01.05.12 |  |
| C.21.01.06.13 | Concreto - solado | 2023-07-25 → 2023-10-25 (+92d) | 2023-07-25 → 2023-10-25 (+92d) |  | 107d → 1d |  |  |
| C.21.01.06.17 | Acero de refuerzo | 2023-07-26 → 2023-10-26 (+92d) | 2023-07-26 → 2023-10-26 (+92d) |  | 107d → 1d |  |  |
| C.21.01.06.18 | Junta Water Stop | 2023-07-26 → 2023-10-26 (+92d) | 2023-07-28 → 2023-10-28 (+92d) |  | 107d → 1d |  |  |
| C.21.01.06.15 | Encofrado recto | 2023-07-27 → 2023-10-27 (+92d) | 2023-07-28 → 2023-10-28 (+92d) |  | 107d → 1d |  |  |
| C.21.01.06.14 | Concreto canal | 2023-07-29 → 2023-10-29 (+92d) | 2023-07-29 → 2023-10-29 (+92d) |  | 107d → 1d |  |  |
| C.21.01.06.16 | Desencofrado | 2023-07-30 → 2023-10-30 (+92d) | 2023-07-31 → 2023-10-31 (+92d) |  | 114d → 12d |  |  |
| C.21.01.06.19 | Compuerta metalica | 2023-07-30 → 2023-10-30 (+92d) | 2023-08-01 → 2023-11-01 (+92d) |  | 107d → 1d |  |  |
| C.21.01.06.12 | Relleno estructural para obras de arte con material propio | 2023-08-01 → 2023-11-01 (+92d) | 2023-08-06 → 2023-11-03 (+89d) | 6d → 3d | 114d → 12d |  | resources HH [162.56 h]; HM [72.1 h] → HH [14.63 h]; HM [6.45 h] |
| 02 | **CAPTACION A3-CP-21-05** | 2023-07-23 → 2023-08-13 (+21d) | 2023-09-03 → 2023-10-25 (+52d) |  |  |  |  |

| ID | Task | Start | Finish | Duration | Total float | Predecessors | Other |
| --- | --- | --- | --- | --- | --- | --- | --- |
| 01 | **MOVIMIENTO DE TIERRAS** | 2023-07-28 → 2023-08-20 (+23d) | 2023-08-19 → 2023-10-15 (+57d) |  |  |  |  |
| C.21.02.01.11 | Excavación estructural para obras de arte | 2023-07-28 → 2023-08-20 (+23d) | 2023-08-01 → 2023-08-24 (+23d) |  | 83d → 21d |  |  |
| C.21.02.01.12 | Relleno estructural para obras de arte con material propio | 2023-08-19 → 2023-10-10 (+52d) | 2023-08-19 → 2023-10-15 (+57d) | 1d → 6d | 98d → 22d |  | resources HH [25.19 h]; HM [11.17 h] → HH [160.95 h]; HM [71.02 h] |
| 02 | **OBRAS DE CONCRETO** | 2023-08-02 → 2023-08-25 (+23d) | 2023-08-25 → 2023-09-17 (+23d) |  |  |  |  |
| C.21.02.02.11 | Concreto - solado | 2023-08-02 → 2023-08-25 (+23d) | 2023-08-02 → 2023-08-25 (+23d) |  | 83d → 21d |  |  |
| C.21.02.02.16 | Acero de refuerzo | 2023-08-03 → 2023-08-26 (+23d) | 2023-08-09 → 2023-09-01 (+23d) |  | 83d → 21d |  |  |
| C.21.02.02.14 | Encofrado | 2023-08-10 → 2023-09-02 (+23d) | 2023-08-14 → 2023-09-06 (+23d) |  | 83d → 21d |  |  |
| C.21.02.02.12 | Concreto - muro | 2023-08-15 → 2023-09-07 (+23d) | 2023-08-20 → 2023-09-12 (+23d) |  | 83d → 21d |  |  |
| C.21.02.02.13 | Concreto Ciclopeo | 2023-08-15 → 2023-09-07 (+23d) | 2023-08-15 → 2023-09-07 (+23d) |  | 88d → 26d |  |  |
| C.21.02.02.15 | Desencofrado | 2023-08-21 → 2023-09-13 (+23d) | 2023-08-25 → 2023-09-17 (+23d) |  | 83d → 21d |  |  |
| 03 | **ESTRUCTURAS METALICAS** | 2023-08-26 → 2023-10-17 (+52d) | 2023-09-03 → 2023-10-25 (+52d) |  |  |  |  |
| C.21.02.03.11 | Compuerta metalica | 2023-08-26 → 2023-10-17 (+52d) | 2023-08-29 → 2023-10-20 (+52d) |  | 83d → 21d | C.21.02.02.15 → C.21.02.02.15, C.21.02.05.12, C.21.02.01.12 | resources HH [103 h]; HM [50 h] → HH [51.5 h]; HM [25 h] |
| C.21.02.03.12 | Rejilla | 2023-08-30 → 2023-10-21 (+52d) | 2023-08-30 → 2023-10-21 (+52d) |  | 83d → 21d |  |  |
| C.21.02.03.13 | Baranda de fierro galvanizado | 2023-08-31 → 2023-10-22 (+52d) | 2023-08-31 → 2023-10-22 (+52d) |  | 83d → 21d |  |  |
| C.21.02.03.14 | Escalera tipo gato | 2023-09-01 → 2023-10-23 (+52d) | 2023-09-01 → 2023-10-23 (+52d) |  | 83d → 21d |  |  |
| C.21.02.03.15 | Tapa metálica | 2023-09-02 → 2023-10-24 (+52d) | 2023-09-03 → 2023-10-25 (+52d) |  | 83d → 21d |  |  |
| 04 | **TUBERÍA** | 2023-07-23 → 2023-08-13 (+21d) | 2023-08-06 → 2023-08-30 (+24d) |  |  |  |  |
| C.21.02.04.12 | Excavación de zanja | 2023-07-23 → 2023-08-13 (+21d) | 2023-07-23 → 2023-08-13 (+21d) |  | 83d → 21d |  |  |
| C.21.02.04.14 | Cama de arena | 2023-07-24 → 2023-08-14 (+21d) | 2023-07-24 → 2023-08-14 (+21d) |  | 83d → 21d |  | resources HH [1.76 h]; HM [0.74 h] → HH [1.75 h]; HM [0.73 h] |
| C.21.02.04.23 | Instalación tubería | 2023-07-25 → 2023-08-15 (+21d) | 2023-07-25 → 2023-08-15 (+21d) |  | 83d → 21d |  |  |
| C.21.02.04.15 | Relleno común para zanjas | 2023-07-26 → 2023-08-16 (+21d) | 2023-07-27 → 2023-08-19 (+23d) | 2d → 4d | 83d → 21d |  | resources HH [16.58 h]; HM [10.46 h] → HH [16.17 h]; HM [10.19 h] |
| C.21.02.04.11 | Excavación estructural para obras de arte | 2023-07-28 → 2023-08-20 (+23d) | 2023-07-28 → 2023-08-20 (+23d) |  | 111d → 39d |  |  |
| C.21.02.04.16 | Concreto solado - Buzones | 2023-07-29 → 2023-08-21 (+23d) | 2023-07-29 → 2023-08-21 (+23d) |  | 111d → 39d |  |  |
| C.21.02.04.20 | Acero de refuerzo | 2023-07-30 → 2023-08-22 (+23d) | 2023-07-31 → 2023-08-23 (+23d) |  | 111d → 39d |  |  |
| C.21.02.04.18 | Encofrado recto | 2023-08-01 → 2023-08-24 (+23d) | 2023-08-01 → 2023-08-24 (+23d) |  | 112d → 40d |  |  |
| C.21.02.04.19 | Encofrado curvo | 2023-08-01 → 2023-08-24 (+23d) | 2023-08-02 → 2023-08-25 (+23d) |  | 111d → 39d |  |  |
| C.21.02.04.17 | Concreto - Buzones | 2023-08-03 → 2023-08-26 (+23d) | 2023-08-03 → 2023-08-26 (+23d) |  | 111d → 39d |  |  |
| C.21.02.04.21 | Desencofrado recto | 2023-08-04 → 2023-08-27 (+23d) | 2023-08-04 → 2023-08-27 (+23d) |  | 112d → 40d |  |  |
| C.21.02.04.22 | Desencodrado curvo | 2023-08-04 → 2023-08-27 (+23d) | 2023-08-05 → 2023-08-28 (+23d) |  | 111d → 39d |  |  |
| C.21.02.04.13 | Relleno estructural para obras de arte con material propio | 2023-08-06 → 2023-08-29 (+23d) | 2023-08-06 → 2023-08-30 (+24d) | 1d → 2d | 111d → 39d |  | resources HH [10.57 h]; HM [4.69 h] → HH [24.94 h]; HM [11.01 h] |
| 05 | **CANALES** | 2023-07-28 → 2023-09-18 (+52d) | 2023-08-25 → 2023-10-16 (+52d) |  |  |  |  |
| C.21.02.05.11 | Excavación estructural para obras de arte | 2023-07-28 → 2023-09-18 (+52d) | 2023-08-03 → 2023-09-24 (+52d) |  | 98d → 21d | C.21.02.04.15 → C.21.02.04.15, C.21.02.02.15, C.21.02.04.13 |  |
| C.21.02.05.13 | Colocación solado | 2023-08-04 → 2023-09-25 (+52d) | 2023-08-04 → 2023-09-25 (+52d) |  | 98d → 21d |  |  |
| C.21.02.05.16 | Acero de refuerzo | 2023-08-05 → 2023-09-26 (+52d) | 2023-08-07 → 2023-09-28 (+52d) |  | 98d → 21d |  |  |
| C.21.02.05.18 | Junta Water Stop | 2023-08-05 → 2023-09-26 (+52d) | 2023-08-11 → 2023-10-02 (+52d) |  | 98d → 21d |  |  |
| C.21.02.05.15 | Encofrado | 2023-08-08 → 2023-09-29 (+52d) | 2023-08-11 → 2023-10-02 (+52d) |  | 98d → 21d |  |  |
| C.21.02.05.14 | Colocación concreto | 2023-08-12 → 2023-10-03 (+52d) | 2023-08-14 → 2023-10-05 (+52d) |  | 98d → 21d |  |  |
| C.21.02.05.17 | Desencofrado | 2023-08-15 → 2023-10-06 (+52d) | 2023-08-18 → 2023-10-09 (+52d) |  | 98d → 21d |  |  |
| C.21.02.05.12 | Relleno estructural para canales | 2023-08-19 → 2023-10-10 (+52d) | 2023-08-25 → 2023-10-16 (+52d) |  | 98d → 21d |  | resources HH [197.05 h]; HM [87.4 h] → HH [195.1 h]; HM [86.09 h] |
| 03 | **RETORNO A3-OA-RE-D-21-55** | 2023-07-23 → 2023-09-18 (+57d) | 2023-09-28 → 2023-10-25 (+27d) |  |  |  |  |
| 01 | **MOVIMIENTO DE TIERRAS** | 2023-07-23 → 2023-09-18 (+57d) | 2023-09-25 → 2023-10-22 (+27d) |  |  |  |  |
| C.21.03.01.11 | Excavación estructural para obras de arte | 2023-07-23 → 2023-09-18 (+57d) | 2023-07-23 → 2023-09-18 (+57d) |  | 58d → 21d | C.70.10.01.11, C.70.10.03.11 → C.70.10.01.11, C.70.10.03.11, C.21.02.02.15 |  |
| C.21.03.01.12 | Relleno estructural para obras de arte con material propio | 2023-09-25 → 2023-10-22 (+27d) | 2023-09-25 → 2023-10-22 (+27d) | 0d → 1d | 62d → 24d |  | resources none → HH [10.46 h]; HM [4.62 h] |
| 02 | **OBRAS DE CONCRETO** | 2023-07-24 → 2023-09-19 (+57d) | 2023-09-24 → 2023-10-21 (+27d) |  |  |  |  |
| C.21.03.02.11 | Concreto - solado | 2023-07-24 → 2023-09-19 (+57d) | 2023-07-24 → 2023-09-19 (+57d) |  | 58d → 21d |  |  |
| C.21.03.02.15 | Acero de refuerzo | 2023-07-25 → 2023-09-20 (+57d) | 2023-09-08 → 2023-10-05 (+27d) | 46d → 16d | 58d → 21d |  |  |
| C.21.03.02.16 | Junta Water Stop | 2023-07-25 → 2023-09-20 (+57d) | 2023-09-14 → 2023-10-11 (+27d) | 52d → 22d | 58d → 21d |  |  |
| C.21.03.02.14 | Encofrado | 2023-09-09 → 2023-10-06 (+27d) | 2023-09-14 → 2023-10-11 (+27d) |  | 58d → 21d |  |  |
| C.21.03.02.12 | Concreto | 2023-09-15 → 2023-10-12 (+27d) | 2023-09-16 → 2023-10-13 (+27d) |  | 60d → 23d |  |  |
| C.21.03.02.13 | Concreto Ciclopeo | 2023-09-15 → 2023-10-12 (+27d) | 2023-09-18 → 2023-10-15 (+27d) |  | 58d → 21d |  |  |
| C.21.03.02.17 | Desencofrado | 2023-09-19 → 2023-10-16 (+27d) | 2023-09-24 → 2023-10-21 (+27d) |  | 58d → 21d |  |  |
| 03 | **ESTRUCTURAS METALICAS** | 2023-09-25 → 2023-10-22 (+27d) | 2023-09-28 → 2023-10-25 (+27d) |  |  |  |  |
| C.21.03.03.11 | Compuerta metalica plana | 2023-09-25 → 2023-10-22 (+27d) | 2023-09-28 → 2023-10-25 (+27d) |  | 58d → 21d |  |  |
| C.21.03.03.12 | Baranda de fierro galvanizado | 2023-09-25 → 2023-10-22 (+27d) | 2023-09-25 → 2023-10-22 (+27d) |  | 61d → 24d |  |  |
| T | **CIERRE** | 2023-11-26 → 2023-11-16 (-10d) |  |  |  |  |  |
| 20 | **DESMOVILIZACIÓN** | 2023-11-26 → 2023-11-16 (-10d) |  |  |  |  |  |
| T.20.11 | Desmovilización equipos | 2023-11-26 → 2023-11-16 (-10d) |  | 4d → 14d |  | C.90.02.04.13, C.70.02.01.03.16, C.70.02.01.03.13, C.70.02.01.02.01.11, C.70.02.01.02.02.11, C.70.02.01.01.11, C.70.02.01.01.14, C.70.02.01.01.13, C.70.02.01.01.12, C.70.10.01.15, C.70.10.02.1.15, C.70.10.02.2.15, C.70.10.02.3.14, C.70.10.03.15, C.70.10.04.15, C.70.10.05.1.15, C.70.10.05.2.15, C.70.11.01.13, C.70.11.02.13, C.60.02.01.02.16, C.60.02.02.02.16, C.60.02.03.13, C.21.01.03.15, C.21.02.03.15, C.21.03.03.12, C.21.03.03.11, C.21.03.01.12, C.60.02.01.01.12, C.60.02.02.01.12, C.21.01.01.12, C.21.01.02.15, C.21.02.01.12, C.21.02.04.13 → C.90.02.04.13, C.70.02.01.03.16, C.70.02.01.03.13, C.70.02.01.02.01.11, C.70.02.01.02.02.11, C.70.02.01.01.11, C.70.02.01.01.14, C.70.02.01.01.13, C.70.02.01.01.12, C.70.10.01.15, C.70.10.02.1.15, C.70.10.02.2.15, C.70.10.02.3.14, C.70.10.03.15, C.70.10.04.15, C.70.10.05.1.15, C.70.10.05.2.15, C.70.11.01.13, C.70.11.02.13, C.60.02.01.02.16, C.60.02.02.02.16, C.60.02.03.13, C.21.01.03.15, C.21.02.03.15, C.21.03.03.12, C.21.03.03.11, C.21.03.01.12, C.60.02.01.01.12, C.60.02.02.01.12, C.21.01.01.12, C.21.01.02.15, C.70.10.05.1.24, C.70.10.03.24 |  |
